# 3GPP_Release-2000

Schedule from MS Project, 2000-01-03 to 2010-09-15, A marks actual dates.

## Calendars

- Standard: Mon-Fri 08:00-12:00, 13:00-17:00; Sat-Sun off.

## Resources

| Resource |
| --- |
| NP |
| N1 |
| N2 |
| N3 |
| N4 |
| N5 |
| TP |
| T1 |
| T2 |
| T3 |
| RP |
| R1 |
| R2 |
| R3 |
| R4 |
| SP |
| S1 |
| S2 |
| S3 |
| S4 |
| S5 |
| PCG |
| GP |
| No |
| CN4 |
| ? |
| WG G2 |
| G2 |
| G1 |
| G4 |
| G3 |
| All |
| Generic |
| MLST |
| G5 |
| S3; G2 |
| WG T2 |
| GP;G1 |
| G4;G5 |
| OMA |
| GP-G2 |
| Yes |
| GP; |
| N4; |
| GP; N1 |
| CT5 |
| C5 |
| C1 |
| C4 |
| C3 |
| C6 |
| G1; |
| 4 |
| ct |
| c;s;r |
| CT;RAN;SA |
| G2, |
| G1; G3 |
| CT6 |
| CT1 |
| CT1, CT3, CT4 |
| C1, C3, C4 |
| CP |
| R5 |
| C |

## Schedule

| ID | WBS | Task | Duration | Start | Finish | Complete | Remaining | Baseline start | Baseline finish | Baseline duration | Total slack | Constraint | Resources | Work | Actual work | Text9 | Text6 | Text1 | Text8 | Text3 | Text5 |
| --- | --- | --- | --- | --- | --- | --- | --- | --- | --- | --- | --- | --- | --- | --- | --- | --- | --- | --- | --- | --- | --- |
| 1 | 1 | VERSION 2007 October 4th | 1d | 2000-01-03 | 2000-01-03 |  |  | 2000-01-03 | 2000-01-03 | 1d | 2335d |  |  |  |  | 2044 |  |  |  |  |  |
| 2 | 2 | "CTRL + a" to display all the 3GPP fields | 1d | 2000-01-03 | 2000-01-03 |  |  | 2000-01-03 | 2000-01-03 | 1d | 2335d |  |  |  |  | 1462 |  |  |  |  |  |
| 3 | 3 | Content of Rel-8 (not frozen) | 1d | 2000-01-03 | 2000-01-03 |  |  | 2000-01-03 | 2000-01-03 | 1d | 2335d |  |  |  |  | 2058 |  |  |  |  |  |
| 5 | 4 | Release 8 Features | 1d? | 2000-01-03 | 2000-01-03 |  |  | 2000-01-03 | 2000-01-03 | 1d? | 2335d |  | CT;RAN;SA | 8h |  |  | Rel-8 |  |  |  |  |
| 6 | 5 | **3G Long Term Evolution - Evolved Packet System RAN part** | 515d? | 2006-09-25 A | 2008-09-12 | 25% | 386.61d? | 2006-09-25 | 2008-09-12 | 515d? | 523d |  | RP | 23080h | 4779.2h |  | Rel-8 | LTE | MCC_RAN |  |  |
| 7 | 5.1 | LTE – Physical Layer | 255d? | 2006-09-25 A | 2007-09-14 | 80% | 51d? | 2006-09-25 | 2007-09-14 | 255d? | 326d | finish no earlier than 2007-09-14 | R1 | 2040h | 1632h |  | Rel-8 | LTE-Phys | MCC_RAN | 36.2xy |  |
| 8 | 5.2 | LTE – Radio Interface Layer 2 and 3 Protocol Aspect | 320d? | 2006-09-25 A | 2007-12-14 | 50% | 160d? | 2006-09-25 | 2007-12-14 | 320d? | 261d | finish no earlier than 2007-12-14 | R2 | 2560h | 1280h |  | Rel-8 | LTE-L23 | MCC_RAN | 36.3xy |  |
| 9 | 5.3 | LTE – eUTRAN Interfaces | 320d? | 2006-09-25 A | 2007-12-14 | 51% | 156.8d? | 2006-09-25 | 2007-12-14 | 320d? | 261d | finish no earlier than 2007-12-14 | R3 | 2560h | 1305.6h |  | Rel-8 | LTE-interfaces | MCC_RAN | 36.4xy |  |
| 10 | 5.4 | LTE – RF Radio Transmission/Reception, System Performance Requirements and Conformance Testing | 385d? | 2006-09-25 A | 2008-03-14 | 2% | 377.3d? | 2006-09-25 | 2008-03-14 | 385d? | 196d | finish no earlier than 2008-03-14 | R4 | 3080h | 61.6h |  | Rel-8 | LTE-RF | MCC_RAN | 36.1xy |  |
| 11 | 5.5 | LTE FDD repeaters | 261d? | 2007-09-14 | 2008-09-12 |  |  | 2007-09-14 | 2008-09-12 | 261d? | 66d | finish no earlier than 2008-09-12 | R4 | 2088h |  |  | Rel-8 | LTE-Repeaters | MCC_RAN | TS 36.x, TS 25.113 |  |
| 12 | 5.6 | **LTE – Terminal Conformance Test Specifications** | 336d? | 2007-06-01 A | 2008-09-12 | 3% | 327.6d? | 2007-06-01 | 2008-09-12 | 336d? | 523d |  | R5 | 6632h | 134.4h |  | Rel-8 | LTE-UEConTest | MCC_RAN |  | catherine.salinoc@nectech.fr |
| 13 | 5.6.1 | 3G Long Term Evolution – Terminal Protocol Conformance Test Specifications | 336d? | 2007-06-01 A | 2008-09-12 | 3% | 325.92d? | 2007-06-01 | 2008-09-12 | 336d? | 66d | finish no earlier than 2008-09-12 | R5 | 2688h | 80.64h |  | Rel-8 | LTE-UEConTest_SIG | Stoyan Baev | TS 36.508, 36.523-1, 36.523-2, 36.523-3 | catherine.salinoc@nectech.fr, Jacob.John@motorola.com |
| 14 | 5.6.2 | 3G Long Term Evolution – Terminal Radio Transmission and Reception Conformance Test Specifications | 336d? | 2007-06-01 A | 2008-09-12 | 2% | 329.28d? | 2007-06-01 | 2008-09-12 | 336d? | 66d | finish no earlier than 2008-09-12 | R5 | 2688h | 53.76h |  | Rel-8 | LTE-UEConTest_RF | Stoyan Baev | TS 36.508, 36.521-1, 36.521-2 | catherine.salinoc@nectech.fr |
| 15 | 6 | **3GPP System Architecture Evolution Specification - Evolved Packet System (non RAN aspects)** | 633d? | 2006-04-12 A | 2008-09-12 | 30% | 444.99d? | 2006-04-12 | 2008-06-20 | 573d? | 523d |  | S2; C1; C3; C4; S1 | 160437h | 34716.2h |  | Rel-8 | SAES | Maurice | 23.228, 23.279 | osok.song@samsung.com |
| 16 | 6.1 | Requirements for evolution of the 3GPP system architecture | 157d? | 2006-06-08 A | 2007-01-12 | 95% | 7.85d? | 2006-06-08 | 2007-01-12 | 157d? | 501d | finish no earlier than 2007-01-12 | S1 | 1256h | 1193.2h |  | Rel-8 | AIPN-SAE | Alain | 22.278 | michael.kurz@t-mobile.at |
| 17 | 6.2 | **High level and common (for all accesses) functions** | 369d? | 2007-01-02 A | 2008-05-30 | 13% | 319.26d? | 2007-01-02 | 2008-05-30 | 369d? | 598d |  | S2; C1; C3; C4 | 30228.8h | 2636.8h |  | Rel-8 | EPS-ComF |  |  |  |
| 18 | 6.2.1 | Stage 2 of High level functions | 309d? | 2007-01-02 A | 2008-03-07 | 80% | 61.8d? | 2007-01-02 | 2007-09-07 | 179d? | 658d | finish no earlier than 2008-03-07 | S2 | 2472h | 1977.6h |  | Rel-8 | SAES-SA-HLF |  |  |  |
| 19 | 6.2.2 | Stage 3 (CT1) for SAE impact on services, network functions and capabilities | 290d? | 2007-02-05 A | 2008-03-14 | 4% | 278.4d? | 2007-02-05 | 2008-03-14 | 290d? | 196d | start no earlier than 2007-02-05 | C1 | 2320h | 92.8h |  | Rel-8 | SAES-St3-CT1imp |  |  |  |
| 20 | 6.2.3 | Stage 3 (CT3) for SAE impact on existing capabilities | 290d? | 2007-02-05 A | 2008-03-14 | 5% | 275.5d? | 2007-02-05 | 2008-03-14 | 290d? | 196d | start no earlier than 2007-02-05 | C3 | 2320h | 116h |  | Rel-8 | SAES-St3-CT3imp |  |  |  |
| 21 | 6.2.4 | Stage 3(CT4) of SAE impact on existing capabilities | 290d? | 2007-02-05 A | 2008-03-14 | 7% | 269.7d? | 2007-02-05 | 2008-03-14 | 290d? | 196d |  | C4 | 2320h | 162.4h |  | Rel-8 | SAES-St3-impacts |  |  |  |
| 22 | 6.2.5 | Stage 3 for Network selection procedures | 290d? | 2007-02-05 | 2008-03-14 |  |  | 2007-02-05 | 2008-03-14 | 290d? | 196d | start no earlier than 2007-02-05 | C1 | 2320h |  |  | Rel-8 | SAES-St3-netsel |  |  |  |
| 23 | 6.2.6 | Stage 3 PCC aspects of SAE | 290d? | 2007-02-05 A | 2008-03-14 | 5% | 275.5d? | 2007-02-05 | 2008-03-14 | 290d? | 196d | start no earlier than 2007-02-05 | C3 | 2320h | 116h |  | Rel-8 | SAES-St3-PCC |  |  |  |
| 24 | 6.2.7 | Stage 3 of Interworking between EPC and external PDNs (SGi) | 290d? | 2007-02-05 | 2008-03-14 |  |  | 2007-02-05 | 2008-03-14 | 290d? | 196d | start no earlier than 2007-02-05 | C3 | 2320h |  |  | Rel-8 | SAES-St3-intwk |  |  |  |
| 25 | 6.2.8 | Stage 3 of SAE / LTE identities | 215d? | 2007-02-05 A | 2007-11-30 | 10% | 193.5d? | 2007-02-05 | 2007-11-30 | 215d? | 271d | finish no earlier than 2007-11-30 | C4 | 1720h | 172h |  | Rel-8 | SAES-St3-IDs |  |  |  |
| 26 | 6.2.9 | Unified guidelines of Diameter usage within 3GPP | 181d? | 2007-09-21 | 2008-05-30 |  |  | 2007-09-21 | 2008-05-30 | 181d? | 141d | finish no earlier than 2008-05-30 | C3 | 1448h |  |  | Rel-8 | SAES-DIAM | Seung Don | TR 29.909 |  |

Notes:
- 6: Text4: Takehiro Nakamura (NTT DoCoMo)
- 7: Text4: Sadayuki Abeta, NTT DoCoMo
- 8: Text4: Benoist Sebire, Nokia
- 9: Text4: Mattias Wahlqvist, Ericsson
- 10: Text4: Frank Lamprecht, Siemens
- 11: Text4: Alf Ahlström, Powerwave Technologies. Ralf Michanikl, Andrew Wireless Corporation
- 12: BB place holder for a number of RAN5 Tasks / Text4: Catherine Salinoc, NEC
- 13: Dependent on RAN as well as on CT/SA WIs / Text4: Catherine Salinoc (NEC), Jacob John (Motorola)
- 14: Text4: Catherine Salinoc, NEC
- 15: S2#52: Specification phase created. New WID approved SA#32 / Text4: Osok Song (Samsung)
- 16: Moved to SA2 at SA#32 / Text4: Michael Kurz (T-Mobile International)
- 26: Approved in CT#37 / Text4: Javier Gonzalez Gallego, Huawei

| ID | WBS | Task | Type | Duration | Start | Finish | Complete | Remaining | Baseline start | Baseline finish | Baseline duration | Total slack | Constraint | Resources | Work | Actual work | Text1 | Text6 | Text5 | Text8 | Text12 |
| --- | --- | --- | --- | --- | --- | --- | --- | --- | --- | --- | --- | --- | --- | --- | --- | --- | --- | --- | --- | --- | --- |
| 27 | 6.3 | **SAE for LTE access** |  | 314d? | 2007-01-02 A | 2008-03-14 | 27% | 229.27d? | 2007-01-02 | 2008-03-14 | 314d? | 653d |  | S2; C1; C3; C4 | 37800h | 8680.1h | SAES-SA-FP_LTE | Rel-8 |  |  |  |
| 28 | 7.2.2.1 | **SAES-SA-FP_LTE with GTP variant** |  | 309d? | 2007-01-02 A | 2008-03-07 | 57% | 132.33d? | 2007-01-02 | 2007-12-03 | 240d? | 658d |  | S2; C4 | 8944h | 3664h | SAES-SA-FP_LTE-GTP | Rel-8 |  |  |  |
| 29 | 6.3.1.1 | Stage 2 for SAES-SA-FP_LTE with GTP variant |  | 309d? | 2007-01-02 A | 2008-03-07 | 90% | 30.9d? | 2007-01-02 | 2007-12-03 | 240d? | 658d | finish no earlier than 2008-03-07 | S2 | 2472h | 2224.8h | SAES-SA-FP_LTE-GTP | Rel-8 |  |  |  |
| 30 | 6.3.1.2 | Stage 3 for GTP protocol |  | 215d? | 2007-02-05 A | 2007-11-30 | 10% | 193.5d? | 2007-02-05 | 2007-11-30 | 215d? | 271d | finish no earlier than 2007-11-30 | C4 | 1720h | 172h | SAES-St3-EPC | Rel-8 |  |  |  |
| 31 | 7.2.2.2 | **SAES-SA-FP_LTE with PMIP variant** |  | 309d? | 2007-01-02 A | 2008-03-07 | 43% | 174.74d? | 2007-01-02 | 2007-12-03 | 240d? | 658d |  | S2 | 8384h | 3642.9h | SAES-SA-FP_LTE-IETF | Rel-8 |  |  |  |
| 32 | 6.3.2.1 | Stage 2 for SAES-SA-FP_LTE with PMIP variant |  | 309d? | 2007-01-02 A | 2008-03-07 | 90% | 30.9d? | 2007-01-02 | 2007-12-03 | 240d? | 658d | finish no earlier than 2008-03-07 | S2 | 2472h | 2224.8h | SAES-SA-FP_LTE-IETF | Rel-8 |  |  |  |
| 33 | 6.3.2.2 | Stage 3 for PMIP protocol within EPC |  | 215d? | 2007-02-05 A | 2007-11-30 | 10% | 193.5d? | 2007-02-05 | 2007-11-30 | 215d? | 271d | finish no earlier than 2007-11-30 | C4 | 1720h | 172h | SAES-St3-EPC | Rel-8 |  |  |  |
| 34 | 6.3.2.3 | Stage 3 for PMIP protocol between EPCs |  | 215d? | 2007-02-05 A | 2007-11-30 | 10% | 193.5d? | 2007-02-05 | 2007-11-30 | 215d? | 271d | finish no earlier than 2007-11-30 | C4 | 1720h | 172h | SAES-St3-EPC_EPC | Rel-8 |  |  |  |
| 35 | 6.3.3 | Stage 3 for UE NAS mobility procedures in idle and active mode |  | 290d? | 2007-02-05 A | 2008-03-14 | 8% | 266.8d? | 2007-02-05 | 2008-03-14 | 290d? | 196d | start no earlier than 2007-02-05 | C1 | 2320h | 185.6h | SAES-St3-NASmob | Rel-8 |  |  |  |
| 36 | 6.3.4 | Stage 3 for Session management, bearer control and QoS aspects |  | 290d? | 2007-02-05 A | 2008-03-14 | 8% | 266.8d? | 2007-02-05 | 2008-03-14 | 290d? | 196d | start no earlier than 2007-02-05 | C1 | 2320h | 185.6h | SAES-St3-BCQOS | Rel-8 |  |  |  |
| 37 | 6.3.5 | Stage 3 for security aspects for LTE Access |  | 290d? | 2007-02-05 A | 2008-03-14 | 8% | 266.8d? | 2007-02-05 | 2008-03-14 | 290d? | 196d | start no earlier than 2007-02-05 | C1 | 2320h | 185.6h | SAES-St3-CT1sec | Rel-8 |  |  |  |
| 38 | 6.3.6 | Stage 3 for QoS mechanisms |  | 290d? | 2007-02-05 | 2008-03-14 |  |  | 2007-02-05 | 2008-03-14 | 290d? | 196d | start no earlier than 2007-02-05 | C3 | 2320h |  | SAES-St3-QoS | Rel-8 |  |  |  |
| 39 | 6.3.7 | Stage 3 for EPC - HSS interface |  | 215d? | 2007-02-05 A | 2007-11-30 | 10% | 193.5d? | 2007-02-05 | 2007-11-30 | 215d? | 271d | finish no earlier than 2007-11-30 | C4 | 1720h | 172h | SAES-St3-EPC_HSS | Rel-8 |  |  |  |
| 40 | 6.4 | **SAE for Interoperation between LTE and legacy cellular PS accesses** |  | 290d? | 2007-02-05 A | 2008-03-14 | 35% | 187.35d? | 2007-02-05 | 2008-03-20 | 294d? | 653d |  | S2; C1; C3; C4 | 18840h | 6668.89h | SAES-SA-FP_3GPP | Rel-8 |  |  |  |
| 41 | 6.4.1 | Stage 2 for Interoperation between LTE and 2G/3G |  | 285d? | 2007-02-05 A | 2008-03-07 | 80% | 57d? | 2007-02-05 | 2007-12-31 | 236d? | 658d | finish no earlier than 2008-03-07 | S2 | 2280h | 1824h | EPSto2_3G | Rel-8 |  |  |  |
| 42 | 6.4.2 | Stage 3 of EPC - GPRS |  | 215d? | 2007-02-05 A | 2007-11-30 | 10% | 193.5d? | 2007-02-05 | 2007-11-30 | 215d? | 271d | finish no earlier than 2007-11-30 | C4 | 1720h | 172h | SAES-St3-EPC_GPRS | Rel-8 |  |  |  |
| 43 | 6.4.3 | Stage 2 for Interoperation between LTE and CDMA2000 |  | 190d? | 2007-06-18 A | 2008-03-07 | 80% | 38d? | 2007-06-18 | 2008-03-20 | 199d? | 658d | finish no earlier than 2008-03-07 | S2 | 1520h | 1216h | EPStoC2k | Rel-8 |  |  |  |
| 44 | 6.4.4 | Stage 3 for Inter-system mobility between E-UTRAN and other access networks |  | 290d? | 2007-02-05 | 2008-03-14 |  |  | 2007-02-05 | 2008-03-14 | 290d? | 196d | start no earlier than 2007-02-05 | C1 | 2320h |  | SAES-St3-intersys | Rel-8 |  |  |  |
| 45 | 6.4.5 | Stage 3 for MME - SGSN "signalling free" protocol |  | 215d? | 2007-02-05 A | 2007-11-30 | 10% | 193.5d? | 2007-02-05 | 2007-11-30 | 215d? | 271d | finish no earlier than 2007-11-30 | C4 | 1720h | 172h | SAES-St3-MME_SGSN | Rel-8 |  |  |  |
| 46 | 6.5 | **SAE for support of non-3GPP accesses** |  | 379d? | 2007-01-02 A | 2008-06-13 | 29% | 268.33d? | 2007-01-02 | 2008-03-14 | 314d? | 588d |  | S2; C1; C3; C4 | 31192h | 6620.59h | SAES-SA-FP_n3GPP | Rel-8 |  |  |  |
| 47 | 7.2.4.1 | Stage 2 for Host-based Mobility aspects |  | 309d? | 2007-01-02 A | 2008-03-07 | 90% | 30.9d? | 2007-01-02 | 2007-12-03 | 240d? | 658d | finish no earlier than 2008-03-07 | S2 | 2472h | 2224.8h | SAES-SA-FP_n3GPP-HBMob | Rel-8 |  |  |  |
| 48 | 7.2.4.2 | Stage 2 for Network-based Mobility aspects |  | 309d? | 2007-01-02 A | 2008-03-07 | 70% | 92.7d? | 2007-01-02 | 2007-12-03 | 240d? | 658d | finish no earlier than 2008-03-07 | S2 | 2472h | 1730.4h | SAES-SA-FP_n3GPP-NBMob | Rel-8 |  |  |  |
| 49 | 6.5.3 | Stage 2 for Optimised Handover with WiMAX |  | 255d? | 2007-06-25 A | 2008-06-13 | 39% | 155d? | 2007-06-25 | 2008-03-07 | 185d? | 588d | finish no earlier than 2008-06-13 | S2 | 2040h | 800h | SAES-SA-FP_n3GPP-OptWIMAX | Rel-8 |  |  |  |
| 50 | 6.5.4 | Stage 3 for Access to the EPC via non-3GPP access networks |  | 290d? | 2007-02-05 A | 2008-03-14 | 4% | 278.4d? | 2007-02-05 | 2008-03-14 | 290d? | 196d | start no earlier than 2007-02-05 | C1 | 2320h | 92.8h | SAES-St3-non-3GPP | Rel-8 |  |  |  |
| 51 | 6.5.5 | Stage 3 for Mobility management based on mobile IP |  | 290d? | 2007-02-05 A | 2008-03-14 | 8% | 266.8d? | 2007-02-05 | 2008-03-14 | 290d? | 196d | start no earlier than 2007-02-05 | C1 | 2320h | 185.6h | SAES-St3-CT1MIP | Rel-8 |  |  |  |
| 52 | 6.5.6 | Stage 3 security aspects for non3GPP Access |  | 290d? | 2007-02-05 A | 2008-03-14 | 8% | 266.8d? | 2007-02-05 | 2008-03-14 | 290d? | 196d | start no earlier than 2007-02-05 | C1 | 2320h | 185.6h | SAES-St3-CT1sec | Rel-8 |  |  |  |
| 53 | 6.5.7 | Stage 3 for interfaces within EPC |  | 67d? | 2007-09-19 | 2007-12-20 |  |  | 2007-09-19 | 2007-12-20 | 67d? | 257d | start no earlier than 2007-09-19 | C4 | 536h |  | EPS-int_ifSt3 | Rel-8 |  |  |  |
| 54 | 6.5.8 | Stage 3 for Interfaces EPC - non-3GPP IP access |  | 215d? | 2007-02-05 A | 2007-11-30 | 10% | 193.5d? | 2007-02-05 | 2007-11-30 | 215d? | 271d | finish no earlier than 2007-11-30 | C4 | 1720h | 172h | SAES-St3-EPC_n3G | Rel-8 |  |  |  |
| 55 | 6.5.9 | Stage 3 for AAA/HSS related |  | 215d? | 2007-02-05 A | 2007-11-30 | 10% | 193.5d? | 2007-02-05 | 2007-11-30 | 215d? | 271d | finish no earlier than 2007-11-30 | C4 | 1720h | 172h | SAES-St3-AAA_HSS | Rel-8 |  |  |  |
| 56 | 6.5.10 | Stage 3 for EPC - AAA interface |  | 215d? | 2007-02-05 A | 2007-11-30 | 10% | 193.5d? | 2007-02-05 | 2007-11-30 | 215d? | 271d | finish no earlier than 2007-11-30 | C4 | 1720h | 172h | SAES-St3-EPC_AAA | Rel-8 |  |  |  |
| 57 | 6.5.11 | Deleted (already covered) SAES-SA-FP_n3GPP Optimised Handover with CDMA | milestone | 0d? | 2007-06-25 A | 2007-06-25 A | 100% |  | 2007-06-25 | 2007-06-25 | 0d? |  | finish no earlier than 2007-06-25 | S2 |  |  | SAES-SA-FP_n3GPP-OptCDMA | Rel-8 |  |  |  |
| 58 | 6.6 | Functions and procedures for SAE to support LTE MBMS |  | 255d? | 2007-06-25 A | 2008-06-13 | 40% | 153d? | 2007-06-25 | 2008-06-13 | 255d? | 588d | finish no earlier than 2008-06-13 | S2 | 2040h | 816h | SAES-SA-FP_LTEMBMS | Rel-8 |  |  |  |
| 59 | 6.7 | Functions and procedures for SAE to support LCS |  | 220d? | 2007-08-13 A | 2008-06-13 | 15% | 187d? | 2007-08-13 | 2008-06-13 | 220d? | 588d | finish no earlier than 2008-06-13 | S2 | 1760h | 264h | SAES-SA-FP_LCS | Rel-8 |  |  |  |
| 60 | 6.8 | Single Radio Voice Call Continuity for 3GPP |  | 379d? | 2007-01-02 A | 2008-06-13 | 50% | 189.5d? | 2007-01-02 | 2008-03-07 | 309d? | 588d | finish no earlier than 2008-06-13 | S2 | 3032h | 1516h | SAES-SA-SR_VCC_3G | Rel-8 |  |  |  |
| 61 | 6.9 | Voice Call Continuity for CDMA2000 1X |  | 255d? | 2007-06-25 A | 2008-06-13 | 60% | 102d? | 2007-06-25 | 2008-03-07 | 185d? | 588d | finish no earlier than 2008-06-13 | S2 | 2040h | 1224h | SAES-SA-VCC_1X | Rel-8 |  |  |  |
| 62 | 6.10 | SAE impacts on IMS |  | 379d? | 2007-01-02 A | 2008-06-13 | 20% | 301.75d? | 2007-01-02 | 2008-03-07 | 309d? | 588d | finish no earlier than 2008-06-13 | S2 | 3032h | 618h | SAES-SA-on_IMS | Rel-8 |  |  |  |
| 63 | 6.11 | SAE aspects of Emergency Calls |  | 245d? | 2007-10-08 | 2008-09-12 |  |  | 2007-10-08 | 2008-06-20 | 185d? | 523d | finish no earlier than 2008-09-12 | S2 | 1960h |  | SAES-SA-EmCall | Rel-8 |  |  |  |
| 64 | 6.12 | Deleted - CT1 aspects of SAES | milestone | 0d? | 2007-09-04 A | 2007-09-27 A | 100% |  | 2007-09-04 | 2007-09-27 | 0d? |  | start no earlier than 2007-09-04 | CP; C1 |  |  | SAES-St3 | Rel-8 |  |  |  |
| 65 | 6.13 | Deleted - CT1 aspects of SAES | milestone | 0d? | 2007-09-04 A | 2007-09-04 A | 100% |  | 2007-09-04 | 2007-09-04 | 0d? |  | start no earlier than 2007-09-04 | C1 |  |  | SAES-St3 | Rel-8 |  |  |  |
| 66 | 6.14 | Deleted - Interoperability | milestone | 0d? | 2008-03-14 A | 2008-03-14 A | 100% |  | 2008-03-14 | 2008-03-14 | 0d? |  | start no earlier than 2008-03-14 | C1 |  |  | SAES-St3-interop | Rel-8 |  |  |  |
| 67 | 6.15 | Deleted - CT3 aspects of SAES | milestone | 0d? | 2007-09-04 A | 2007-09-04 A | 100% |  | 2007-09-04 | 2007-09-04 | 0d? |  | start no earlier than 2007-09-04 | C3 |  |  | SAES-St3 | Rel-8 |  |  |  |
| 68 | 6.16 | Deleted - CT4 aspects of SAES | milestone | 0d? | 2007-09-04 A | 2007-09-04 A | 100% |  | 2007-09-04 | 2007-09-04 | 0d? |  | start no earlier than 2007-09-04 | C4 |  |  | SAES-St3 | Rel-8 |  |  |  |
| 69 | 6.17 | Deleted - UE to EPC NAS signalling (incl. MBMS and QoS aspects) | milestone | 0d? | 2008-03-14 A | 2008-03-14 A | 100% |  | 2008-03-14 | 2008-03-14 | 0d? |  | start no earlier than 2008-03-14 | C1 |  |  | SAES-St3-sig | Rel-8 |  |  |  |
| 70 | 6.18 | Deleted -User and Control plane protocols | milestone | 0d? | 2007-09-21 A | 2007-09-21 A | 100% |  | 2007-09-21 | 2007-09-21 | 0d? |  | start no earlier than 2007-09-21 | C4 |  |  | SAES-St3-prot | Rel-8 |  |  |  |
| 71 | 6.19 | Deleted - GPRS enhancements for LTE access | milestone | 0d? | 2007-09-04 A | 2007-09-04 A | 100% |  | 2007-09-04 | 2007-09-04 | 0d? |  | start no earlier than 2007-09-04 | S2 |  |  | SAES-GPRS_LTE | Rel-8 | chris.pudney@vodafone.com | Maurice |  |
| 72 | 6.20 | Deleted - Architecture enhancements for non-3GPP accesses | milestone | 0d? | 2007-09-04 A | 2007-09-04 A | 100% |  | 2007-09-04 | 2007-09-04 | 0d? |  | start no earlier than 2007-09-04 | S2 |  |  | SAES-non_3GPP | Rel-8 | Irfan.Ali@motorola.com | Maurice |  |
| 73 | 6.21 | Deleted: Stage 2 of architecture for the 3GPP System Architecture Evolution | milestone | 0d? | 2007-10-02 A | 2007-10-02 A | 100% |  | 2007-10-02 | 2007-10-02 | 0d? |  | start no earlier than 2007-10-02 | S2 |  |  | SAES-St2 | Rel-8 | chris.pudney@vodafone.com | Maurice | SP-34 |
| 74 | 6.22 | deleted - SA aspects of System Architecture Evolution |  | 384d? | 2006-04-12 A | 2007-10-02 A | 100% |  | 2006-04-12 | 2007-10-02 | 384d? |  | finish no earlier than 2007-10-02 | S2 | 3072h | 3072h | SAES-SA | Rel-8 |  |  |  |
| 75 | 7 | GERAN support for GERAN - 3G Long Term Evolution interworking |  | 381d? | 2006-09-08 A | 2008-02-22 | 25% | 285.75d? | 2006-09-08 | 2008-02-22 | 381d? | 211d | finish no earlier than 2008-02-22 | GP | 3048h | 762h | GELTE | Rel-8 | sergio.parolari@nsn.com, vlora.rexhepi@nokia.com | Paolo |  |

Notes:
- 59: SA2 need RAN outputs (RAN dependencies)
- 63: Progress expected S2#60
- 68: Text3: 29.803
- 71: SP-34: GPRS enhancements for LTE access item created. / Text3: 23.401 / Text4: Chris Pudney (Vodafone)
- 72: SP-34: Architecture enhancements for non-3GPP accesses item created. / Text3: 23.402 / Text4: Irfan Ali (Motorola)
- 73: THIS LINE IS DELETED, replaced by the 2 Architecture parallel tracks. / Text3: 23.002, 23.060, 23.107, 23.203, 23.228, 23.234, 23.246, 23.271, 23.279 / Text4: Chris Pudney (Vodafone)
- 74: S2 internal target is September 2007
- 75: Text3: 24.008, 43.055, 43.129, 43.246, 44.018, 44.060, 45.002, 45.008, 45.010, 48.008,48.018, 51.010 / Text4: Vlora Rexhepi - van der Pol, Nokia Corporation, / Sergio Parolari, Nokia Siemens Networks S.p.A.

| ID | WBS | Task | Type | Duration | Start | Finish | Complete | Remaining | Baseline start | Baseline finish | Baseline duration | Total slack | Constraint | Resources | Work | Actual work | Text1 | Text4 | Text6 | Text3 | Text5 | Text8 |
| --- | --- | --- | --- | --- | --- | --- | --- | --- | --- | --- | --- | --- | --- | --- | --- | --- | --- | --- | --- | --- | --- | --- |
| 76 | 8 | **Contact Manager for 3GPP UICC applications** |  | 447d? | 2006-06-22 A | 2008-03-07 | 61% | 174.72d? | 2006-06-22 | 2008-03-07 | 447d? | 658d |  | C6 | 10232h | 4054.4h | eUPHBOOK | Claus Dietze (Giesecke & Devrient) | Rel-8 |  |  |  |
| 77 | 8.1 | Requirements for Contact Manager |  | 392d? | 2006-06-22 A | 2007-12-21 | 90% | 39.2d? | 2006-06-22 | 2007-12-21 | 392d? | 256d | finish no earlier than 2007-12-21 | C6 | 3136h | 2822.4h | eUPHBOOK-St1 | Claus Dietze (Giesecke & Devrient) | Rel-8 | 21.111 |  |  |
| 78 | 8.2 | External interface for eUPHBOOK |  | 220d? | 2007-05-07 A | 2008-03-07 | 65% | 77d? | 2007-05-07 | 2008-03-07 | 220d? | 201d | finish no earlier than 2008-03-07 | C6 | 1760h | 1144h | eUPHBOOK-Spec | Claus Dietze (Giesecke & Devrient) | Rel-8 | 31.xyz |  |  |
| 79 | 8.3 | Internal interface for eUPHBOOK |  | 220d? | 2007-05-07 A | 2008-03-07 | 5% | 209d? | 2007-05-07 | 2008-03-07 | 220d? | 201d | finish no earlier than 2008-03-07 | C6 | 1760h | 88h | eUPHBOOK-Spec | Claus Dietze (Giesecke & Devrient) | Rel-8 | 31.xyz |  |  |
| 80 | 8.4 | Deleted - Implementation of eUPHBOOK | milestone | 0d? | 2007-06-21 A | 2007-06-21 A | 100% |  | 2007-06-21 | 2007-06-21 | 0d? |  | start no earlier than 2007-06-21 | C6 |  |  | eUPHBOOK-St23 |  | Rel-8 | 31.102 |  |  |
| 81 | 9 | **Enhancements for VGCS Applications** |  | 528d? | 2006-03-15 A | 2008-03-21 | 60% | 210.89d? | 2006-03-15 | 2008-03-21 | 528d? | 648d |  | S1 | 17256h | 7979.6h | EVA | Amar Deol, Nortel Networks | Rel-8 | 42.068 | deola@nortel.com | Alain |
| 82 | 9.1 | SA1 aspects for EVA |  | 191d? | 2006-03-15 A | 2006-12-06 A | 100% |  | 2006-03-15 | 2006-12-06 | 191d? |  | finish no earlier than 2006-12-06 | S1 | 1528h | 1528h | EVA-s1 | Amar Deol, Nortel Networks | Rel-8 | 42.068 | deola@nortel.com | Alain |
| 83 | 9.2 | C1 aspects for EVA |  | 471d? | 2006-06-02 A | 2008-03-21 | 55% | 211.95d? | 2006-06-02 | 2008-03-21 | 471d? | 191d | finish no earlier than 2008-03-21 | C1 | 3768h | 2072.4h | EVA | Milan Patel | Rel-8 | 43.068, 44.068 | milanpa@nortel.com | Andrijana |
| 84 | 9.3 | C4 aspects for EVA |  | 391d? | 2006-06-02 A | 2007-11-30 | 80% | 78.2d? | 2006-06-02 | 2007-11-30 | 391d? | 271d | finish no earlier than 2007-06-01 | C4 | 3128h | 2502.4h | EVA-c4 |  | Rel-8 | 29.002 |  | Kimmo |
| 85 | 9.4 | GERAN2 Aspects of EVA |  | 431d? | 2006-06-30 A | 2008-02-22 | 50% | 215.5d? | 2006-06-30 | 2008-02-22 | 431d? | 211d | finish no earlier than 2008-02-22 | G2 | 3448h | 1724h | EVA-EVGCSA | Frank Billenkamp (Nortel Networks) | Rel-8 | 44.018, 48.008 | frank.billenkamp@nortel.com | Gert |
| 86 | 9.5 | VGCS/VBS and GPRS Interactions |  | 145d? | 2007-09-03 | 2008-03-21 |  |  | 2007-09-03 | 2008-03-21 | 145d? | 191d | finish no earlier than 2008-03-21 | S1 | 1160h |  |  | Ling Liu | Rel-8 | 42.068, 42.069 |  |  |
| 87 | 10 | **Multimedia Priority Service** |  | 462d? | 2006-06-08 A | 2008-03-14 | 48% | 240.45d? | 2006-06-08 | 2008-03-14 | 462d? | 653d |  | S1; C1; C3; C4 | 15724.8h | 4888.8h | PRIOR | Jim Garrahan (Telcordia) | Rel-8 | 22.153 | jgarraha@telcordia.com | Alain |
| 88 | 10.1 | Service Requirements for PRIOR |  | 336d? | 2006-06-08 A | 2007-09-20 | 80% | 67.2d? | 2006-06-08 | 2007-09-20 | 336d? | 322d | finish no earlier than 2007-09-20 | S1 | 2688h | 2150.4h | PRIOR-EMR | Jim Garrahan (Telcordia) | Rel-8 | 22.153 | jgarraha@telcordia.com | Alain |
| 89 | 10.2 | Stage 3 (CT1) for PRIOR |  | 336d? | 2006-12-01 A | 2008-03-14 | 50% | 168d? | 2006-12-01 | 2008-03-14 | 336d? | 196d | finish no earlier than 2008-03-14 | C1 | 2688h | 1344h | PRIOR-MM | Keith Drage, Alcatel-Lucent | Rel-8 | 24.229 | drage@Alcatel-Lucent.com | Andrijana |
| 90 | 10.3 | Stage 3 (CT3) for PRIOR |  | 126d? | 2007-09-21 | 2008-03-14 |  |  | 2007-09-21 | 2008-03-14 | 126d? | 196d | finish no earlier than 2008-03-14 | C3 | 1008h |  | PRIOR-MM |  | Rel-8 | 29.212, 29.213, 29.214, 29.163 |  | Seung Don |
| 91 | 10.4 | Stage 3 (CT4) for PRIOR |  | 126d? | 2007-09-21 A | 2008-03-14 | 5% | 119.7d? | 2007-09-21 | 2008-03-14 | 126d? | 196d | finish no earlier than 2008-03-14 | C4 | 1008h | 50.4h | PRIOR-MM |  | Rel-8 | 23.008, 29.228, 29.229 |  | Kimmo |
| 92 | 11 | **System enhancements for interconnection interfaces between two IMSs** |  | 468d? | 2006-08-16 A | 2008-05-30 | 29% | 333.61d? | 2006-08-16 | 2008-05-30 | 468d? | 598d |  | S2 | 9760h | 1985.56h | IMS_NNI | Steve Tsang-Kwong-U, Orange | Rel-8 |  |  |  |
| 93 | 11.1 | Stage 2 of IMS_NNI |  | 131d? | 2007-06-22 A | 2007-12-21 A | 100% |  | 2007-06-22 | 2007-12-21 | 131d? |  | finish no earlier than 2007-12-21 | S2 | 1048h | 1048h | IMS_NNI | Delphin Barankanira, Orange | Rel-8 |  |  |  |
| 94 | 11.2 | Protocol impact of FBI for TISPAN R2 |  | 152d? | 2006-08-16 | 2007-03-15 |  |  | 2006-08-16 | 2007-03-15 | 152d? | 457d | finish no earlier than 2007-03-15 | C1 | 1216h |  | FBI2-TISP2-c1 |  | Rel-8 |  |  |  |
| 95 | 11.3 | IMS inter-operator service interconnection interface |  | 261d? | 2007-06-01 A | 2008-05-30 | 10% | 234.9d? | 2007-06-01 | 2008-05-30 | 261d? | 598d | finish no earlier than 2008-05-30 | C3 | 2088h | 208.8h | FBI2-IOPSI | Mauro Ficaccio (Telecom Italia) | Rel-8 | 29.865 | mauro.ficaccio@telecomitalia.it | Seung Don |
| 96 | 11.4 | Charging harmonization for NGN between 3GPP and ATIS-TMOC |  | 51d? | 2006-09-28 A | 2006-12-07 A | 100% |  | 2006-09-28 | 2006-12-07 | 51d? |  | finish no earlier than 2006-12-07 | S5 | 408h | 408h | FBI2-TISP2-CH | Amdocs | Rel-8 | 32.297 |  | Adrian |
| 97 | 11.5 | Deleted (never approved) - Stage 2 of FBI for TISPAN R2 - Rel 8 |  | 157d? | 2007-04-26 A | 2007-11-30 | 5% | 149.15d? | 2007-04-26 | 2007-11-30 | 157d? | 271d | start no earlier than 2007-04-26 | S2 | 1256h | 62.8h | FBI2-TISP2-s2 |  | Rel-8 |  |  |  |
| 98 | 12 | Service and Capability for Core IMS - inclusion of TISPAN requirements |  | 75d? | 2007-09-03 | 2007-12-14 |  |  | 2007-09-03 | 2007-12-14 | 75d? | 261d | finish no earlier than 2007-12-14 | S1 | 600h |  | CIMS8-TIS | Susana Sabater (Ericsson) | Rel-8 | 22.228, 22.115, 22.101 |  |  |
| 99 | 13 | Merging TISPAN Multimedia Telephony [requirements] for Common IMS |  | 65d? | 2007-09-10 | 2007-12-07 |  |  | 2007-09-10 | 2007-12-07 | 65d? | 266d | finish no earlier than 2007-12-07 | S1 | 520h |  | TMMTEL | Joerg Swetina (NSN) | Rel-8 | 22.173 |  |  |
| 100 | 14 | IMS Centralised Service Control |  | 75d? | 2007-09-03 | 2007-12-14 |  |  | 2007-09-03 | 2007-12-14 | 75d? | 261d | finish no earlier than 2007-12-14 | S1 | 600h |  | ICSRA | Randy Wohlert (AT&T) | Rel-8 | 22.101 |  |  |

Notes:
- 77: C6-43: Name Changed to Requirements for Contact Manager. Expected completion updated from CT#34 to CT#35.
- 78: New TS 31.xyz to be produced
- 79: Created at CT#37
- 83: Not reviewed at WG, directly from CT#37
- 84: CT4#32: Crs are presented and in principle agreed, waiting for the approval of stage2...
- 87: Created by MCC to group 320023 (Stage 1) and 340012 (Stage 3) wrongly shown as idependent Features
- 88: Official name is "Multimedia Priority Service" but this is identical to UID 31041
- 89: "CT1" corrected into "C1"
- 92: Name changed from "System enhancements for TISPAN Rel2" at SA36
- 94: To be reviewed in CT1
- 95: Approved at CT#36
- 96: 09/2006 SA#33 WID approved
- 97: It might be more appropriate to introduce the individual functions instead of a global title. SA2 WID expected at SA#36

| ID | WBS | Task | Duration | Start | Finish | Complete | Remaining | Baseline start | Baseline finish | Baseline duration | Total slack | Constraint | Resources | Work | Actual work | Text1 | Text3 | Text4 | Text5 | Text6 | Text8 |
| --- | --- | --- | --- | --- | --- | --- | --- | --- | --- | --- | --- | --- | --- | --- | --- | --- | --- | --- | --- | --- | --- |
| 101 | 15 | **IMS Service Brokering enhancements** | 69d? | 2005-12-07 A | 2006-03-13 A | 100% |  | 2005-12-07 | 2006-03-13 | 69d? |  |  | S1 | 1104h | 1104h | ISB | 22.228 | John-Luc Bakker (Telcordia) | jbakker@telcordia.com | Rel-8 | Alain |
| 102 | 15.1 | Stage 1 of ISB | 69d? | 2005-12-07 A | 2006-03-13 A | 100% |  | 2005-12-07 | 2006-03-13 | 69d? |  | finish no earlier than 2006-03-13 | S1 | 552h | 552h | ISB-s1 | 22.228 | John-Luc Bakker (Telcordia) | jbakker@telcordia.com | Rel-8 | Alain |
| 103 | 16 | IMS System enhancements for corporate network access | 256d? | 2007-06-22 A | 2008-06-13 | 10% | 230.4d? | 2007-06-22 | 2007-12-21 | 131d? | 588d | finish no earlier than 2008-06-13 | S2 | 2048h | 204.8h | IMS_Corp |  | Delphin Barankanira, Orange |  | Rel-8 |  |
| 104 | 17 | **IMS Enhancements for support of Packet Cable access** | 272d? | 2006-12-06 A | 2007-12-20 | 55% | 123.67d? | 2006-12-06 | 2007-12-20 | 272d? | 714d |  | S2 | 18744h | 8242.26h | PktCbl |  |  |  | Rel-8 | Maurice |
| 105 | 17.1 | **IMS Enhancements for Security Requirements in Support of Cable Deployments** | 272d? | 2006-12-06 A | 2007-12-20 | 36% | 174.73d? | 2006-12-06 | 2007-12-20 | 272d? | 714d |  | S3 | 7232h | 1808h | PktCbl-Sec | 33.203, 33.210, 33.220, 24.229 | Steve Dotson (Cablelabs) | s.dotson@cablelabs.com | Rel-8 | Dioniso |
| 106 | 17.1.1 | S3 Aspects of PktCbl-Sec | 272d? | 2006-12-06 A | 2007-12-20 | 50% | 136d? | 2006-12-06 | 2007-12-20 | 272d? | 257d | finish no earlier than 2007-12-20 | S3 | 2176h | 1088h | PktCbl-Sec | 33.203, 33.210, 33.220, 24.229 | Steve Dotson (Cablelabs) | s.dotson@cablelabs.com | Rel-8 | Dioniso |
| 107 | 17.1.2 | CT1 Aspects of PktCbl-Sec | 180d? | 2007-03-26 A | 2007-11-30 | 40% | 108d? | 2007-03-26 | 2007-11-30 | 180d? | 271d | start no earlier than 2007-03-26 | C1 | 1440h | 576h | PktCbl-Sec | 24.229, 24.109 | David Hancock (CableLabs) | D.Hancock@ CableLabs.com | Rel-8 | Andrijana |
| 108 | 17.1.3 | CT4 Aspects of PktCbl-Sec | 180d? | 2007-03-26 A | 2007-11-30 | 10% | 162d? | 2007-03-26 | 2007-11-30 | 180d? | 271d | start no earlier than 2007-03-26 | C4 | 1440h | 144h | PktCbl-Sec | 29.228, 29229, 23.008, | David Hancock (CableLabs) | D.Hancock@ CableLabs.com | Rel-8 | Kimmo |
| 109 | 17.2 | **IMS Enhancements for Cable Client Types and Deployment Models** | 216d? | 2007-02-05 A | 2007-12-03 | 55% | 98.18d? | 2007-02-05 | 2007-12-03 | 216d? | 727d |  | S2 | 4896h | 1930.35h | PktCbl-Deploy |  |  |  | Rel-8 |  |
| 110 | 17.2.1 | Architecture aspects of PktCbl-Deploy | 216d? | 2007-02-05 A | 2007-12-03 A | 100% |  | 2007-02-05 | 2007-12-03 | 216d? |  | finish no earlier than 2007-12-03 | S2 | 1728h | 1728h | PktCbl-Deploy |  |  |  | Rel-8 |  |
| 111 | 17.2.2 | CT1 aspects of PktCbl-Deploy | 180d? | 2007-03-26 | 2007-11-30 |  |  | 2007-03-26 | 2007-11-30 | 180d? | 271d | start no earlier than 2007-03-26 | C1 | 1440h |  | PktCbl-Deploy | 24.229, 24167 | David Hancock (CableLabs) | D.Hancock@ CableLabs.com | Rel-8 | Andrijana |
| 112 | 17.3 | **IMS Inter-working Aspects in Support of Cable Regulatory requirements** | 215d? | 2007-02-05 A | 2007-11-30 | 89% | 22.76d? | 2007-02-05 | 2007-11-30 | 215d? | 728d |  | S2 | 4440h | 3317.29h | PktCbl-Intw | 23.228 | Bernie McKibben (CableLabs) | B.McKibben@CableLabs.com | Rel-8 | Maurice |
| 113 | 17.3.1 | Architecture aspects of PktCbl-Interwork | 160d? | 2007-02-05 A | 2007-09-14 A | 100% |  | 2007-02-05 | 2007-09-14 | 160d? |  | start no earlier than 2007-02-05 | S2 | 1280h | 1280h | PktCbl-Intw | 23.228 | Bernie McKibben (CableLabs) | B.McKibben@CableLabs.com | Rel-8 | Maurice |
| 114 | 17.3.2 | CT1 aspects of PktCbl-Interwork | 180d? | 2007-03-26 A | 2007-11-30 | 80% | 36d? | 2007-03-26 | 2007-11-30 | 180d? | 271d | start no earlier than 2007-03-26 | C1 | 1440h | 1152h | PktCbl-Intw | 24.229 | David Hancock (CableLabs) | D.Hancock@ CableLabs.com | Rel-8 | Andrijana |
| 115 | 18 | eCall Data Transfer – Requirements | 51d? | 2006-09-28 A | 2006-12-07 A | 100% |  | 2006-09-28 | 2006-12-07 | 51d? |  | finish no earlier than 2006-12-07 | S1 | 408h | 408h | EData | 22.101, 22.105 | Rhys Robinson (Airbiquity) | rrobinson@airbiquity.com | Rel-8 | Alain |
| 116 | 19 | Enhancements to BS30 Bearer service for Videotelephony | 51d? | 2007-01-04 A | 2007-03-15 | 10% | 45.9d? | 2007-01-04 | 2007-03-15 | 51d? | 457d | finish no earlier than 2007-03-15 | S1 | 408h | 40.8h | BS30 | 22.002, 22.004, 22.101, 22.105, 24.008 | Andre Jarvis (3) | andre.jarvis@three.co.uk | Rel-8 | Alain |
| 117 | 20 | Local Charging Zone Requirements | 51d? | 2006-09-28 A | 2006-12-07 A | 100% |  | 2006-09-28 | 2006-12-07 | 51d? |  | finish no earlier than 2006-12-07 | S1 | 408h | 408h | LCZR | 22.115 | Hong Liu (China Mobile) | liuhongyfw@chinamobile.com | Rel-8 | Alain |
| 118 | 21 | Services Alignment and Migration | 256d? | 2006-12-06 A | 2007-11-28 | 65% | 89.6d? | 2006-12-06 | 2007-11-28 | 256d? | 273d | finish no earlier than 2007-09-20 | S1 | 2048h | 1331.2h | ServAl | 22.182 | Feng Lingjuan (China Mobile) | fenglingjuan@chinamobile.com | Rel-8 | Alain |
| 119 | 22 | Value Added Services for Short Message Service | 140d? | 2007-09-10 | 2008-03-21 |  |  | 2007-09-10 | 2008-03-21 | 140d? | 191d | finish no earlier than 2008-03-21 | S1 | 1120h |  | VAS4SMS | new 22.xxx | Wu Bin (China Mobile) | wubin@chinamobile.com | Rel-8 |  |
| 120 | 23 | End-User Identity | 75d? | 2007-09-03 | 2007-12-14 |  |  | 2007-09-03 | 2007-12-14 | 75d? | 261d | finish no earlier than 2007-12-14 | S1 | 600h |  | EUI | 22.101 | Joerg Swetina (Nokia Siemens Network) | Joerg.Swetina@Siemens.com | Rel-8 |  |
| 121 | 24 | **Customised Alerting Tone** | 264d? | 2006-12-06 A | 2007-12-10 | 60% | 106.74d? | 2006-12-06 | 2007-12-10 | 264d? | 722d |  | S1 | 4336h | 2582.88h | CAT | 22.182 | Feng Lingjuan (China Mobile) | (fenglingjuan@chinamobile.com) | Rel-8 | Alain |
| 122 | 24.1 | Stage 1 for CAT | 207d? | 2006-12-06 A | 2007-09-20 | 80% | 41.4d? | 2006-12-06 | 2007-09-20 | 207d? | 322d | start no earlier than 2006-12-06 | S1 | 1656h | 1324.8h | CAT | 22.182 | Feng Lingjuan (China Mobile) | (fenglingjuan@chinamobile.com) | Rel-8 | Alain |
| 123 | 24.2 | Customized multimedia information services - inclusion of TISPAN requirements | 71d? | 2007-09-03 | 2007-12-10 |  |  | 2007-09-03 | 2007-12-10 | 71d? | 265d | finish no earlier than 2007-12-10 | S1 | 568h |  | TISCMI | 22.182 | Peter Bleckert (Ericsson) |  | Rel-8 |  |
| 124 | 25 | I-WLAN Network Selection Principle | 1d? | 2007-09-03 A | 2007-09-03 A | 100% |  | 2007-09-03 | 2007-09-03 | 1d? |  |  | S1 | 8h | 8h | IWLANNSP | 22.234 | Chris Friel (O2) | chris.friel@o2.com | Rel-8 | Alain |

Notes:
- 107: Supporting Companies:
- 108: Supporting Companies:
- 111: Supporting Companies:
- 112: Supporting Companies: CableLabs, Nortel, Cisco, Samsung, Alcatel-Lucent, Siemens, Motorola, Hewlett-Packard, Ericsson
- 113: Supporting Companies: CableLabs, Nortel, Cisco, Samsung, Alcatel-Lucent, Siemens, Motorola, Hewlett-Packard, Ericsson
- 114: Supporting Companies:
- 118: previous names were Services Alignment, Service Migration
- 121: Acronym changed from "CusAlert" to "CAT"

| ID | WBS | Task | Type | Duration | Start | Finish | Complete | Remaining | Baseline start | Baseline finish | Baseline duration | Total slack | Constraint | Resources | Work | Actual work | Text1 | Text4 | Text5 | Text6 | Text8 | Text7 |
| --- | --- | --- | --- | --- | --- | --- | --- | --- | --- | --- | --- | --- | --- | --- | --- | --- | --- | --- | --- | --- | --- | --- |
| 125 | 26 | **Service-Level Interworking for Messaging Services** |  | 249d? | 2007-03-26 A | 2008-03-07 | 80% | 49.8d? | 2007-03-26 | 2007-12-24 | 195d? | 658d |  | S1 | 3808h | 2508.8h | MESSIW | Liu Ling (Huawei); Duan Xiaoqin (Huawei) | ling.liu@huawei.com; duanxiaoqin@huawei.com | Rel-8 | Alain |  |
| 126 | 26.1 | Stage 1 aspects of MESSIW | milestone | 0d? | 2007-03-26 A | 2007-03-26 A | 100% |  | 2007-03-26 | 2007-03-26 | 0d? |  | finish no earlier than 2007-12-01 | S1 |  |  | MESSIW-St1 | Liu Ling (Huawei) | ling.liu@huawei.com | Rel-8 | Alain |  |
| 127 | 26.2 | Stage 2 aspects of MESSIW |  | 227d? | 2007-04-26 A | 2008-03-07 | 80% | 45.4d? | 2007-04-26 | 2007-12-24 | 173d? | 658d | finish no earlier than 2008-03-07 | S2 | 1816h | 1452.8h | MESSIW-St2 | Patrice Hede (Huawei) | patrice.hede@huawei.com | Rel-8 | Maurice |  |
| 128 | 27 | **OAM&P 8** |  | 1039d? | 2006-09-22 A | 2010-09-15 | 26% | 764.43d? | 2005-09-02 | 2008-12-15 | 857d? | 0d |  | S5 | 36897.1h | 8019.2h | OAM8 |  |  | Rel-8 | Adrian |  |
| 129 | 27.1 | Integration Reference Point (IRP) Methodology |  | 855d? | 2007-06-07 A | 2010-09-15 | 40% | 513d? | 2005-09-02 | 2008-12-15 | 857d? | 0d | finish no earlier than 2008-12-11 | S5 | 6840h | 2736h |  | Ericsson |  | Rel-8 |  |  |
| 130 | 27.2 | Advanced Alarming on Itf-N (Study + Implementation) |  | 596d? | 2007-06-07 A | 2009-09-17 | 40% | 357.6d? | 2005-09-02 | 2007-12-14 | 596d? | 259d | finish no earlier than 2007-12-14 | S5 | 4768h | 1907.2h |  | NSN |  | Rel-8 |  |  |
| 131 | 27.3 | CN CS Bearer Transport Network (BTN) relative NRM |  | 655d? | 2007-06-07 A | 2009-12-09 | 20% | 524d? | 2005-09-02 | 2007-12-14 | 596d? | 200d | finish no earlier than 2008-03-06 | S5 | 5240h | 1048h |  | China Mobile |  | Rel-8 |  |  |
| 132 | 27.4 | IP bearer network Performance measurement definitions |  | 596d? | 2007-06-07 A | 2009-09-17 | 30% | 417.2d? | 2005-09-02 | 2007-12-14 | 596d? | 259d | finish no earlier than 2007-12-14 | S5 | 4768h | 1430.4h |  | China Mobile |  | Rel-8 |  |  |
| 133 | 27.5 | HSUPA performance measurements |  | 196d? | 2007-06-07 A | 2008-03-06 | 20% | 156.8d? | 2007-06-07 | 2008-03-06 | 196d? | 659d | finish no earlier than 2008-03-06 | S5 | 1568h | 313.6h |  | China Mobile |  | Rel-8 |  |  |
| 134 | 27.6 | Key Performance Indicator |  | 196d? | 2007-06-07 A | 2008-03-06 | 20% | 156.8d? | 2007-06-07 | 2008-03-06 | 196d? | 659d | finish no earlier than 2008-03-06 | S5 | 1568h | 313.6h |  | China Mobile |  | Rel-8 |  |  |
| 135 | 27.7 | Subscriber and Equipment Trace for eUTRAN and EPC |  | 194d? | 2007-09-17 A | 2008-06-12 | 10% | 174.6d? |  |  |  | 589d | start no earlier than 2007-09-17 | S5 | 1552h | 155.2h |  | Ericsson |  | Rel-8 |  |  |
| 136 | 27.8 | End point modelling for reference point |  | 124d? | 2007-09-17 A | 2008-03-06 | 10% | 111.6d? |  |  |  | 659d | start no earlier than 2007-09-17 | S5 | 992h | 99.2h |  | Motorola |  | Rel-8 |  |  |
| 137 | 27.9 | Service Level Tracing in IMS |  | 379.14d? | 2006-09-22 A | 2008-04-10 |  | 379.14d? | 2006-09-22 | 2008-04-10 | 379.14d? | 634.04d | finish no earlier than 2008-03-15 | C1 | 3033.12h |  | OAM7-Trace | Jari Jansson, Nokia | jari.jansson@nokia.com | Rel-8 | Andrijana |  |
| 138 | 27.10 | Deleted - Network Infrstructure Management 8 | milestone | 0d? | 2007-07-13 A | 2007-07-13 A | 100% |  | 2007-07-13 | 2007-07-13 | 0d? |  | finish no earlier than 2007-07-13 | S5 |  |  |  |  |  | Rel-8 | Adrian |  |
| 139 | 27.11 | Deleted - Performance Management 8 |  | 1d? | 2007-07-13 A | 2007-07-13 A | 100% |  | 2007-07-13 | 2007-07-13 | 1d? |  |  | S5 | 8h | 8h |  |  |  | Rel-8 | Adrian |  |
| 140 | 27.12 | Deleted - Trace Management 8 |  | 1d? | 2007-06-22 A | 2007-06-22 A | 100% |  | 2007-06-22 | 2007-06-22 | 1d? |  | start no earlier than 2007-06-22 | S5 | 8h | 8h |  |  |  | Rel-8 |  |  |
| 141 | 28 | **Registration in Densely-populated area** |  | 330d? | 2007-03-12 A | 2008-06-13 | 41% | 194.58d? | 2007-03-12 | 2007-12-07 | 195d? | 588d |  | S1 | 4184h | 662.4h | RED | Tsuyoshi Takakura (NTT DoCoMo Inc.) | takakurat@s1.nttdocomo.co.jp | Rel-8 | Alain |  |
| 142 | 28.1 | Stage 1 for RED |  | 4d? | 2007-03-12 A | 2007-03-15 | 90% | 0.4d? | 2007-03-12 | 2007-03-15 | 4d? | 914d | start no earlier than 2007-03-12 | S1 | 32h | 28.8h | RED | Tsuyoshi Takakura (NTT DoCoMo Inc.) | takakurat@s1.nttdocomo.co.jp | Rel-8 | Alain |  |
| 143 | 28.2 | Stage2 for Registration in Densely-populated area (RED) |  | 189d? | 2007-09-25 A | 2008-06-13 | 40% | 113.4d? | 2007-09-25 | 2007-12-07 | 54d? | 588d | finish no earlier than 2008-06-13 | S2 | 1512h | 604.8h | RED-St2 | Itsuma Tanaka (NTT DoCoMo Inc.) | tanakai@nttdocomo.co.jp | Rel-8 | Maurice |  |
| 144 | 29 | Lawful Interception in the 3GPP Rel-8 |  | 265d? | 2007-03-12 A | 2008-03-14 | 20% | 212d? | 2007-03-12 | 2008-03-14 | 265d? | 653d | finish no earlier than 2008-03-14 | S3 | 2120h | 424h | LI8 | Berthold Wilhelm (BMWi/BNetzA) | berthold.wilhelm@bnetza.de | Rel-8 | Dioniso |  |
| 145 | 30 | **Rel-8 Improvements of the Radio Interface** |  | 314d? | 2007-03-05 A | 2008-05-15 | 33% | 209.56d? | 2007-03-05 | 2008-05-15 | 314d? | 609d |  | RP | 11408h | 3820h | RInImp8 |  |  | Rel-8 | Claude |  |
| 146 | 30.1 | UMTS 1500 MHz |  | 140d? | 2007-03-05 A | 2007-09-14 A | 100% |  | 2007-03-05 | 2007-09-14 | 140d? |  | finish no earlier than 2007-09-14 | R4 | 1120h | 1120h | RInImp8-UMTS1500 | Takehiro Nakamura | NTT DoCoMo | Rel-8 | Claude | TSG |
| 147 | 30.2 | UMTS 700 MHz |  | 215d? | 2007-03-05 A | 2007-12-28 | 25% | 161.25d? | 2007-03-05 | 2007-12-28 | 215d? | 708d | start no earlier than 2007-03-05 | R4 | 1720h | 430h | RInImp8-UMTS700 | Tuomo Saynajakangas | Nokia | Rel-8 | Claude | TSG |
| 148 | 30.3 | UMTS 2300 MHz |  | 215d? | 2007-03-05 A | 2007-12-28 | 5% | 204.25d? | 2007-03-05 | 2007-12-28 | 215d? | 708d | start no earlier than 2007-03-05 | R4 | 1720h | 86h | RInImp8-UMTS2300 | Marc Grant | marc.grant@cingular.com | Rel-8 | Claude | TSG |
| 149 | 30.4 | Further Improved Minimum Performance Requirements for HSDPA UE (FDD) - Two-Branch Interference Cancellation |  | 215d? | 2007-03-05 A | 2007-12-28 | 80% | 43d? | 2007-03-05 | 2007-12-28 | 215d? | 708d | finish no earlier than 2007-12-28 | R4 | 1720h | 1376h | RInImp8-2BIC | Marc Grant, Cingular | marc.grant@cingular.com | Rel-8 | MCC_RAN |  |
| 150 | 30.5 | CS Voice Service over HSPA |  | 172d? | 2007-07-19 | 2008-03-14 |  |  | 2007-07-19 | 2008-03-14 | 172d? | 653d | start no earlier than 2007-07-19 | R2 | 1376h |  | RInImp8-CsHspa | Woonhee Hwang, Nokia Siemens Networks | woonhee.hwang@nsn.com | Rel-8 | MCC_RAN |  |
| 151 | 30.6 | Performance requirements for 15 code reception with 16QAM/QPSK |  | 175d? | 2007-09-14 | 2008-05-15 |  |  | 2007-09-14 | 2008-05-15 | 175d? | 609d | start no earlier than 2007-09-14 | R2 | 1400h |  | RInImp8-Hsdpa15codes | Tim Frost, Vodafone | tim.frost@vodafone.com | Rel-8 | MCC_RAN |  |

Notes:
- 125: WID updated by S2-57, Approved at SP-36 / Text3: 22.105, 22.340, 23.abc, TS 23.xyz (TBD)
- 126: Text3: 22.105, 22.340
- 127: WID updated by S2-57, Approved at SP-36. Rapporteur updated S2#59. TR for Information to SA#38 / Text3: 22.105, 22.340, 23.811
- 128: Created to encompass the Rel7 Work Tasks shifted to Rel8
- 129: Request to TSG#35 to move to Release 8 / Text3: new 32.155
- 130: Request to TSG#35 to move to Release 8 / Text3: new 32.121/2/3/5
- 131: Request to TSG#35 to move to Release 8 / Text3: new 32.74x
- 132: Request to TSG#35 to move to Release 8 / Text3: 32.321/2/3/5
- 133: Text3: 32.405
- 134: Text3: 32.405
- 135: Text3: 32.42x, 32.44x
- 136: Text3: 32.152, 32.62/3/4x, 32.73x
- 137: Cannot proceed without substancial IETF contribution / Text3: 24.229, 24.167, 29.228,29.229,29.163,29.332
- 138: Created to encompass the Rel7 Work Tasks shifted to Rel8
- 139: Created to encompass the Rel7 Work Tasks shifted to Rel8
- 140: Created to encompass the Rel7 Work Tasks shifted to Rel8
- 141: One CR at SA #35 / Text3: 22.101
- 142: One CR at SA #35 / Text3: 22.101
- 143: Approved as BB at SP-37 / Text3: 23.880
- 144: End date to be determined when Rel-8 frozen. / Text3: 33.106, 33.107, 33.108
- 146: Text3: TS25.101, TS25.104, TS25.133, TS25.141, TS25.331, TS25.942, TS25.306, TS25.307, TS34.121
- 147: Text3: TS25.101, TS25.104, TS25.133, TS25.141, TS25.331, TS25.942, TS25.306, TS25.307, TS34.121
- 148: Text3: TS25.101, TS25.104, TS25.133, TS25.141, TS25.331, TS25.942, TS25.306, TS25.307, TS34.121
- 150: Text3: 25.323, 25.331, 25.322
- 151: Text3: 25.101

| ID | WBS | Task | Type | Duration | Start | Finish | Complete | Remaining | Baseline start | Baseline finish | Baseline duration | Total slack | Constraint | Resources | Work | Actual work | Text1 | Text4 | Text5 | Text6 | Text8 | Text7 |
| --- | --- | --- | --- | --- | --- | --- | --- | --- | --- | --- | --- | --- | --- | --- | --- | --- | --- | --- | --- | --- | --- | --- |
| 152 | 31 | **Personal Network Management** |  | 835d? | 2005-07-11 A | 2008-09-19 | 38% | 518.83d? | 2005-07-11 | 2008-09-19 | 835d? | 518d |  | S1 | 18124.8h | 6215.11h | PNM | Armin Toepfer, Vodafone | armin.toepfer@vodafone.com | Rel-8 | Alain |  |
| 153 | 31.1 | Stage 1 of PNM |  | 276d? | 2005-07-11 A | 2006-07-31 | 85% | 41.4d? | 2005-07-11 | 2006-07-31 | 276d? | 1077d | start no earlier than 2005-07-11 | S1 | 2208h | 1876.8h | PNM |  |  | Rel-8 | Alain |  |
| 154 | 31.2 | Deleted - Actual Requirements of PNM | milestone | 0d? | 2007-03-26 A | 2007-03-26 A | 100% |  | 2007-03-26 | 2007-03-26 | 0d? |  | finish no earlier than 2007-03-26 | C1 |  |  | PNM | Yang Lu, |  | Rel-8 |  |  |
| 155 | 31.3 | Stage 2 of PNM |  | 263d? | 2007-03-26 A | 2008-03-26 | 70% | 78.9d? | 2007-03-26 | 2008-03-26 | 263d? | 645d | finish no earlier than 2008-03-26 | C1 | 2104h | 1472.8h | PNM | Yang Lu, |  | Rel-8 |  |  |
| 156 | 31.4 | **Stage 3 of PNM** |  | 390d? | 2007-03-26 A | 2008-09-19 | 5% | 370.5d? | 2007-03-26 | 2008-09-19 | 390d? | 518d |  | C1 | 7195.2h | 359.76h | PNM | Yang Lu, |  | Rel-8 |  |  |
| 157 | 31.4.1 | CT1 aspects of PNM |  | 390d? | 2007-03-26 A | 2008-09-19 | 5% | 370.5d? | 2007-03-26 | 2008-09-19 | 390d? | 518d | finish no earlier than 2008-09-19 | C1 | 3120h | 156h | PNM | Yang Lu, |  | Rel-8 |  |  |
| 158 | 31.4.2 | CT4 aspects of PNM |  | 263d? | 2007-03-26 A | 2008-03-26 | 5% | 249.85d? | 2007-03-26 | 2008-03-26 | 263d? | 645d | start no earlier than 2007-03-26 | C4 | 2104h | 105.2h | PNM | Yang Lu, |  | Rel-8 |  |  |
| 159 | 32 | **Charging Management small Enhancements** |  | 656d? | 2006-03-16 A | 2008-09-18 | 51% | 319.36d? | 2006-05-08 | 2007-12-14 | 420d? | 519d |  | S5 | 11824h | 3572.27h | CH8 | Orange |  | Rel-8 | Adrian |  |
| 160 | 32.1 | Online charging correlation |  | 420d? | 2006-03-16 A | 2007-12-14 | 70% | 126d? | 2006-05-08 | 2007-12-14 | 420d? | 718d | finish no earlier than 2007-12-14 | S5 | 3360h | 2352h |  | Orange |  | Rel-8 |  |  |
| 161 | 32.2 | SMS online charging |  | 185d? | 2007-06-07 A | 2008-02-20 | 75% | 46.25d? | 2007-04-02 | 2007-09-12 | 118d? | 670d | finish no earlier than 2007-12-14 | S5 | 1480h | 1110h |  | Vodafone |  | Rel-8 |  |  |
| 162 | 32.3 | Add Interconnection Border Control Function (IBCF) to IMS Charging |  | 264d? | 2007-09-17 A | 2008-09-18 | 5% | 250.8d? |  |  |  | 519d | finish no earlier than 2008-09-18 | S5 | 2112h | 105.6h |  | ALU |  | Rel-8 |  |  |
| 163 | 33 | **OSA Rel-8** |  | 336d? | 2007-08-23 | 2008-12-04 |  |  | 2007-08-23 | 2008-12-04 | 336d? | 464d |  | S1 | 17776h |  | OSA8 | Orange |  | Rel-8 | Alain | TSG |
| 164 | 33.1 | OSA Stage 1 - Service Requirements |  | 336d? | 2007-08-23 | 2008-12-04 |  |  | 2007-08-23 | 2008-12-04 | 336d? | 464d | finish no earlier than 2008-12-04 | S1 | 2688h |  | OSA8 |  |  | Rel-8 | Alain | TSG |
| 165 | 33.2 | OSA Stage 1 - NGN Service Requirement |  | 140d? | 2007-09-03 | 2008-03-14 |  |  | 2007-09-03 | 2008-03-14 | 140d? | 653d | finish no earlier than 2008-03-14 | S1 | 1120h |  | OSA8 | Song Dong (Orange) |  | Rel-8 |  |  |
| 166 | 33.3 | **OSA Stage 2/3 enhancements** |  | 291d? | 2007-10-25 | 2008-12-04 |  |  | 2007-10-25 | 2008-12-04 | 291d? | 464d |  | C5 | 13968h |  | OSA8 | Orange |  | Rel-8 | Adrian |  |
| 167 | 33.3.1 | Ensure Parlay-X composable with identity management frameworks, in particular Liberty Alliance |  | 291d? | 2007-10-25 | 2008-12-04 |  |  | 2007-10-25 | 2008-12-04 | 291d? | 464d | finish no earlier than 2008-12-04 | C5 | 2328h |  | OSA8 | AePONA |  | Rel-8 |  |  |
| 168 | 33.3.2 | Parlay-X Content Management web service (store/manage meta-data) |  | 291d? | 2007-10-25 | 2008-12-04 |  |  | 2007-10-25 | 2008-12-04 | 291d? | 464d | finish no earlier than 2008-12-04 | C5 | 2328h |  | OSA8 | ETRI |  | Rel-8 |  |  |
| 169 | 33.3.3 | Parlay-X Policy web service |  | 291d? | 2007-10-25 | 2008-12-04 |  |  | 2007-10-25 | 2008-12-04 | 291d? | 464d | finish no earlier than 2008-12-04 | C5 | 2328h |  | OSA8 | ETRI |  | Rel-8 |  |  |
| 170 | 33.3.4 | Parlay-X Terminal status web service |  | 291d? | 2007-10-25 | 2008-12-04 |  |  | 2007-10-25 | 2008-12-04 | 291d? | 464d | finish no earlier than 2008-12-04 | C5 | 2328h |  | OSA8 | Orange |  | Rel-8 |  |  |
| 171 | 33.3.5 | Identify communication format used by a particular application |  | 291d? | 2007-10-25 | 2008-12-04 |  |  | 2007-10-25 | 2008-12-04 | 291d? | 464d | finish no earlier than 2008-12-04 | C5 | 2328h |  | OSA8 | AePONA |  | Rel-8 |  |  |
| 172 | 34 | **Rel-8 RAN improvements** |  | 335d? | 2007-06-04 A | 2008-09-12 | 4% | 321.87d? | 2007-06-04 | 2008-09-12 | 335d? | 523d |  | RP | 10888h | 426.61h | RANimp |  |  | Rel-8 |  |  |
| 173 | 34.1 | Combination of 64QAM and MIMO for HSDPA (FDD) |  | 201d? | 2007-06-04 A | 2008-03-10 | 20% | 160.8d? | 2007-06-04 | 2008-03-10 | 201d? | 657d | finish no earlier than 2008-03-10 | R1 | 1608h | 321.6h | RANimp-64QamMimoHsdpa | Johan Bergman, Ericsson | Johan.Bergman@ericsson.com | Rel-8 | MCC_RAN |  |
| 174 | 34.2 | Improved L2 for uplink |  | 127d? | 2007-09-14 | 2008-03-10 |  |  | 2007-09-14 | 2008-03-10 | 127d? | 657d | start no earlier than 2007-09-14 | R2 | 1016h |  | RANimp-UplinkL2dataRates | Janne Peisa, Ericsson | Janne.Peisa@ericsson.com | Rel-8 | MCC_RAN |  |
| 175 | 34.3 | Enhanced Uplink for CELL_FACH State in FDD |  | 175d? | 2007-09-14 | 2008-05-15 |  |  | 2007-09-14 | 2008-05-15 | 175d? | 609d | start no earlier than 2007-09-14 | R2 | 1400h |  | RANimp-UplinkEnhState | Markus Wimmer, Nokia Siemens Networks | markus.wimmer@nsn.com | Rel-8 | MCC_RAN |  |
| 176 | 34.4 | Enhanced UE DRX for FDD |  | 261d? | 2007-09-14 | 2008-09-12 |  |  | 2007-09-14 | 2008-09-12 | 261d? | 523d | finish no earlier than 2008-09-12 | R2 | 2088h |  | RANimp-DRX | Luís Barreto, Nokia | luis.barreto@nokia.com | Rel-8 | MCC_RAN |  |
| 177 | 34.5 | Enhancements for SRNS Relocation Procedure |  | 131d? | 2007-09-14 | 2008-03-14 |  |  | 2007-09-14 | 2008-03-14 | 131d? | 653d | finish no earlier than 2008-03-14 | R3 | 1048h |  | RANimp-SrnsReloc | Masatoshi Nakamata, Nokia Siemens Networks | masatoshi.nakamata@nsn.com | Rel-8 | MCC_RAN |  |
| 178 | 34.6 | Enhancements for FDD HSPA Evolution |  | 131d? | 2007-09-14 | 2008-03-14 |  |  | 2007-09-14 | 2008-03-14 | 131d? | 653d | finish no earlier than 2008-03-14 | R3 | 1048h |  | RANimp-HSPAEvo | Masatoshi Nakamata, Nokia Siemens Networks | masatoshi.nakamata@nsn.com | Rel-8 | MCC_RAN |  |
| 179 | 35 | Security Enhancements for IMS |  | 272d? | 2007-03-01 | 2008-03-14 |  |  | 2007-03-01 | 2008-03-14 | 272d? | 653d | finish no earlier than 2008-03-14 | S3 | 1608h |  | IMS-Sec | Bengt Sahlin (Ericsson) |  | Rel-8 | Dioniso |  |

Notes:
- 152: Moved from FS section Feb 06. SP-33: Create new section to capture the PNM stage 2 aspects and identify any impacts to existing stage 2 specifications. S2 added as secondary responsibility
- 153: Moved from FS section Feb 06: SP-33: Create new section to capture the PNM stage 2 aspects and identify any impacts to existing stage 2 specifications. / Text3: 22.259, 23.818
- 155: Text3: 23.259
- 156: Moved from FS section Feb 06: SP-33: Create new section to capture the PNM stage 2 aspects and identify any impacts to existing stage 2 specifications.
- 157: Text3: 24.229, 24.259
- 158: Text3: 23.008, 23.018, 29.002, 29.328, 29.329
- 159: Text3: 32.2xy
- 160: WID approved SA#35 / Text3: 32.240, 32.296
- 161: Text3: new 32.274, CR 32.240 / 299/ 298
- 162: Text3: 32.240/260/298/299
- 164: az: WID URL corrected / Text3: 22.127
- 165: Text3: 22.127
- 166: Text3: 23.198, 29.198/9
- 167: Text3: 29.199-xy
- 168: Text3: 29.199-NEW
- 169: Text3: 29.199-NEW
- 170: Text3: 29.199-NEW
- 171: Text3: 29.199-xy
- 173: Text3: 25.308,25.211,25.212,25.213,25.306,25.331,25.433,25.435,25.423,25.425,25.101,25.104,25.141
- 174: Text3: 25.319, 25.301, 25.306, 25.321, 25.331, 25.433, 25.435, 25.423, 25.425, 25.427
- 175: Text3: 25.309, 25.211, 25.214, 25.321, 25.331, 25.423, 25.433
- 176: Text3: 25.306, 25.308, 25.321, 25.331, 25.423
- 177: Text3: 25.306, 25.308, 25.321, 25.331, 25.423, 25.433, 25.214, 25.133
- 178: Text3: 25.423, 25.427, 25.433
- 179: WID approved at SP-36 / Text3: 33.203, 33.828, 33.803

| ID | WBS | Task | Duration | Start | Finish | Complete | Remaining | Baseline start | Baseline finish | Baseline duration | Total slack | Constraint | Resources | Work | Actual work | Text1 | Text4 | Text5 | Text6 | Text8 | Text3 | Text12 | Text7 |
| --- | --- | --- | --- | --- | --- | --- | --- | --- | --- | --- | --- | --- | --- | --- | --- | --- | --- | --- | --- | --- | --- | --- | --- |
| 180 | 36 | **Support of (G)MSC-S – (G)MSC-S Nc Interface based on the SIP-I protocol** | 266d? | 2007-09-14 A | 2008-09-19 | 3% | 257.13d? | 2007-09-14 | 2008-09-19 | 266d? | 518d |  | C4 | 8512h | 283.73h | SIP_Nc | David Hutton (Vodafone Group) | David.Hutton@VODAFONE.COM | Rel-8 | Kimmo |  |  |  |
| 181 | 36.1 | SIP-I based circuit-switched core network; Stage 2 | 266d? | 2007-09-14 A | 2008-09-19 | 5% | 252.7d? | 2007-09-14 | 2008-09-19 | 266d? | 518d | finish no earlier than 2008-09-19 | C4 | 2128h | 106.4h | SIP_Nc-St2 |  |  | Rel-8 | Kimmo | TS 23.231 |  |  |
| 182 | 36.2 | Application of SIP-I Protocols to Circuit Switched (CS) core network architecture; Stage 3 | 266d? | 2007-09-14 A | 2008-09-19 | 5% | 252.7d? | 2007-09-14 | 2008-09-19 | 266d? | 518d | finish no earlier than 2008-09-19 | C4 | 2128h | 106.4h | SIP_Nc-St3 |  |  | Rel-8 | Kimmo | TS 29.231 |  |  |
| 183 | 36.3 | Interworking between the 3GPP CS domain with SIP-I as signalling protocol and other networks | 266d? | 2007-09-14 | 2008-09-19 |  |  | 2007-09-14 | 2008-09-19 | 266d? | 518d | finish no earlier than 2008-09-19 | C3 | 2128h |  | SIP_Nc-IW |  |  | Rel-8 | Seung Don | TS 29.xyz |  |  |
| 184 | 37 | IMS Stage-3 IETF Protocol Alignment | 316d? | 2007-06-22 A | 2008-09-05 | 10% | 284.4d? | 2007-06-22 | 2008-09-05 | 316d? | 528d | start no earlier than 2007-06-22 | C1 | 2528h | 252.8h | IMSProtoc2 | Keith Drage (Alcatel-Lucent) | drage@alcatel-lucent.com | Rel-8 | Andrijana | 23.218, 24.229 |  |  |
| 185 | 38 | New multicarrier BTS class | 126d? | 2007-08-31 | 2008-02-22 |  |  | 2007-08-31 | 2008-02-22 | 126d? | 668d | finish no earlier than 2008-02-22 | G1 | 1008h |  | MCBTS | Thomas BITZER (Alcatel-Lucent) | thomas.bitzer@alcatel-lucent.de | Rel-8 | Paolo | 45.005, 45.050, 51.021 |  |  |
| 186 | 39 | MS Antenna Performance Evaluation Method and Requirements | 801d? | 2005-01-28 A | 2008-02-22 | 80% | 160.2d? | 2005-01-28 | 2008-02-22 | 801d? | 668d | finish no earlier than 2008-02-22 | GP | 6408h | 5126.4h | APEMR | Ulf.Tegth (TeliaSonera) | Ulf.Tegth@teliasonera.com | Rel-8 | Paolo | 25.914, 25.144, 45.005 |  |  |
| 187 | 40 | U-TDOA Enhancement | 201d? | 2007-05-18 A | 2008-02-22 | 25% | 150.75d? | 2007-05-18 | 2008-02-22 | 201d? | 668d | finish no earlier than 2008-02-22 | GP | 1608h | 402h | GUTEN | Ms. Terri L. Brooks, TruePosition, Inc. | terri.brooks@trueposition.com | Rel-8 | Paolo | 43.059, 45.008, 48.071 |  |  |
| 188 | 41 | **GAN Enhancements** | 261d? | 2007-08-31 | 2008-08-29 |  |  | 2007-08-31 | 2008-08-29 | 261d? | 533d |  | GP | 5184h |  | GANENH | Mohammed Versi, T-Mobile USA Inc. | mohammed.versi@t-mobile.com | Rel-8 | Paolo | 43.318, 44.318, 51.010 |  |  |
| 189 | 41.1 | Update to GAN specifications | 126d? | 2007-08-31 | 2008-02-22 |  |  | 2007-08-31 | 2008-02-22 | 126d? | 668d | finish no earlier than 2008-02-22 | GP | 1008h |  | GANENH-SPEC | Mohammed Versi, T-Mobile USA Inc. | mohammed.versi@t-mobile.com | Rel-8 | Paolo, Gert | 43.318, 44.318 |  |  |
| 190 | 41.2 | Update TS 51.010 Mobile Station (MS) Conformance Specification for GAN Enhancements | 261d? | 2007-08-31 | 2008-08-29 |  |  | 2007-08-31 | 2008-08-29 | 261d? | 533d | finish no earlier than 2008-08-29 | GP | 2088h |  | GANENH-MStest | Mohammed Versi, T-Mobile USA Inc. | mohammed.versi@t-mobile.com | Rel-8 | Stoyan | 51.010 |  |  |
| 191 | 42 | (Small) Technical Enhancements and Improvements for Rel-8 | 400d? | 2007-01-01 | 2008-07-11 |  |  | 2007-01-01 | 2008-07-11 | 400d? | 568d | start no earlier than 2007-01-01 | All | 3200h |  | TEI8 |  |  | Rel-8 |  |  |  |  |
| 192 | 43 | Delete - was a Rel7 item - LCS for 3GPP Interworking WLAN | 245d? | 2006-10-23 | 2007-09-28 |  |  | 2006-10-23 | 2007-09-28 | 245d? | 773d | finish no earlier than 2007-09-28 | S2 | 1960h |  | LCS4_IWLAN | Donghee Shim (LG Electronics Inc.) | dhshim@lge.com | Rel-8 | Maurice | 23.234, 23.271, 23.167 | S2-56 |  |
| 193 | 44 | Deleted (never approved) FBI Phase 2 | 349d? | 2006-06-30 | 2007-10-31 |  |  | 2006-06-30 | 2007-10-31 | 349d? | 750d | start no earlier than 2006-06-30 | S2 | 2792h |  | FBI2 |  |  | Rel-8 | Maurice |  |  | TSG |
| 194 | 45 | **Interworking Wireless LAN Mobility** | 196d? | 2007-09-14 A | 2008-06-13 | 25% | 147d? | 2004-06-28 | 2006-03-15 | 448d? | 588d |  | S2 | 1267.2h | 316.8h | IWLAN_Mob |  |  | Rel-8 | Maurice |  |  | TSG |
| 195 | 45.1 | Stage 2: Interworking Wireless LAN Mobility | 158.4d? | 2007-09-14 A | 2008-06-13 | 25% | 118.8d? | 2004-06-28 | 2005-03-16 | 188d? | 588d | finish no earlier than 2008-06-13 | S2 | 1267.2h | 316.8h | IWLAN_Mob |  |  | Rel-8 | Maurice |  |  | TSG |
| 196 | 46 | Rel-8 Feasibility Studies | 1104d? | 2004-06-28 A | 2008-09-18 | 57% | 470.08d? | 2004-06-28 | 2008-09-18 | 1104d? | 519d |  | CT;RAN;SA | 8832h | 5071.4h |  |  |  | Rel-8 |  |  |  |  |
| 197 | 47 | Study on Facilitating Machine to Machine Communication in GSM and UMTS (M2M) | 161d? | 2005-11-04 A | 2006-06-16 | 90% | 16.1d? | 2005-11-04 | 2006-06-16 | 161d? | 1108d | finish no earlier than 2006-06-16 | S1 | 1288h | 1159.2h | M2M | Juergen Merkel, Siemens AG |  | Rel-8 | Alain | 22.868 |  |  |
| 198 | 48 | FS on Network Composition | 211d? | 2005-12-07 A | 2006-09-27 A | 100% |  | 2005-12-07 | 2006-09-27 | 211d? |  | finish no earlier than 2006-09-27 | S1 | 1688h | 1688h | NetComp | Joerg Swetina (Siemens) | joerg.swetina@siemens.com | Rel-8 | Alain | 22.980 |  |  |
| 199 | 49 | Study on Charging Aspects of 3GPP System Evolution | 179d? | 2007-04-02 A | 2007-12-06 | 60% | 71.6d? | 2007-04-02 | 2007-12-06 | 179d? | 724d | finish no earlier than 2007-12-06 | S5 | 1432h | 859.2h | FSSAEcharg | NSN |  | Rel-8 |  | TR 32.820 | SP-32 |  |
| 200 | 50 | **All-IP Network (AIPN)** | 448d? | 2004-06-28 A | 2006-03-15 A | 100% |  | 2004-06-28 | 2006-03-15 | 448d? |  |  | S1 | 8672h | 8672h | AIPN | Chris Sachno (NTT DoCoMo) | c.masyu@nttdocomo.co.jp | Rel-8 | Alain | 22.978 |  | TSG |
| 201 | 50.1 | All-IP Network Feasibility Study | 188d? | 2004-06-28 A | 2005-03-16 A | 100% |  | 2004-06-28 | 2005-03-16 | 188d? |  | start no earlier than 2004-06-28 | S1 | 1504h | 1504h | AIPFS | Chris Sachno (NTT DoCoMo) | c.masyu@nttdocomo.co.jp | Rel-8 | Alain | 22.978 |  | TSG |
| 202 | 50.2 | Stage1 | 448d? | 2004-06-28 A | 2006-03-15 A | 100% |  | 2004-06-28 | 2006-03-15 | 448d? |  | finish no earlier than 2006-03-15 | S1 | 3584h | 3584h | AIPN | Chris Sachno (NTT DoCoMo) | c.masyu@nttdocomo.co.jp | Rel-8 | Alain | 22.258 |  | TSG |
| 203 | 51 | Study on Stage 2 aspects of IMS Service Brokering | 520d? | 2006-06-19 A | 2008-06-13 | 55% | 234d? | 2006-06-19 | 2008-03-14 | 455d? | 588d | finish no earlier than 2008-06-13 | S2 | 4160h | 2288h | ISB_ST2_SDY | Raquel Morera (Telcordia); F. Joe Lin (Telcordia) | raquel@research.telcordia.com | Rel-8 | Maurice | 23.810 |  |  |
| 204 | 52 | Study of Requirements of IMS Multimedia Conferencing | 205d? | 2006-06-08 A | 2007-03-21 | 70% | 61.5d? | 2006-06-08 | 2007-03-21 | 205d? | 910d | finish no earlier than 2007-03-21 | S1 | 1640h | 1148h | SI-IMSconf | Zheng Jianping (China Mobile ) | zhengjianping@chinamobile.com | Rel-8 | Alain | 22.948 |  |  |
| 205 | 53 | Study on support of a Public Warning System | 205d? | 2006-06-08 A | 2007-03-21 | 70% | 61.5d? | 2006-06-08 | 2007-03-21 | 205d? | 910d | start no earlier than 2006-06-08 | S1 | 1640h | 1148h | FSPWS | Mark Young (T-mobile) | mark.younge@t-mobile.com | Rel-8 | Alain | 22.968 |  |  |
| 206 | 54 | Study on Protection against SMS and MMS spam | 402d? | 2006-06-08 A | 2007-12-21 | 10% | 361.8d? | 2006-06-08 | 2007-12-21 | 402d? | 713d | finish no earlier than 2007-12-21 | S3 | 3216h | 321.6h | CPSMal | Eric Gauthier (Orange SA) | eric.gauthier@orange.ch | Rel-8 | Dioniso | 33.9xx |  |  |
| 207 | 55 | Study of VCC support for Emergency Calls | 532d? | 2006-06-08 A | 2008-06-20 | 30% | 372.4d? | 2006-06-08 | 2008-06-20 | 532d? | 583d | finish no earlier than 2008-06-20 | S2 | 4256h | 1276.8h | FSVCCEm | Ricky Kaura, Nortel |  | Rel-8 | Maurice | 23.826 |  |  |
| 208 | 56 | Study on Centralised IMS Service Control | 290d? | 2006-10-23 A | 2007-12-01 | 85% | 43.5d? | 2006-10-23 | 2007-12-01 | 290d? | 728d | finish no earlier than 2007-12-01 | S2 | 2320h | 1972h | IMS_CSC | Andy Bennett (Alcatel-Lucent) | andybennett@Alcatel-Lucent.com | Rel-8 | Maurice | 23.892 |  |  |
| 209 | 57 | Study on IMS utilizing multicast bearer services | 444d? | 2006-03-22 A | 2007-12-03 A | 100% |  | 2006-03-22 | 2007-12-03 | 444d? |  | finish no earlier than 2007-12-03 | S2 | 3552h | 3552h | FS-MLTICAST-IMS | Fiona Zhu (Siemens AG) |  | Rel-8 | Maurice | 23.847 |  |  |
| 210 | 58 | Study on Paging Permission with Access Control | 256d? | 2006-09-28 A | 2007-09-20 | 80% | 51.2d? | 2006-09-28 | 2007-09-20 | 256d? | 779d | finish no earlier than 2007-09-20 | S1 | 2048h | 1638.4h | PPAC | Katsuhiro Noguchi (NTT DoCoMo Inc.) | noguchi@nttdocomo.co.jp | Rel-8 | Alain | 22.908 |  |  |
| 211 | 59 | Study on Non 3GPP access NSP | 207d? | 2006-12-06 A | 2007-09-20 | 40% | 124.2d? | 2006-12-06 | 2007-09-20 | 207d? | 779d | start no earlier than 2006-12-06 | S1 | 1656h | 662.4h | N3GtoNSP | Chris Friel (O2) | chris.friel@o2.com | Rel-8 | Alain | 22.812 |  |  |
| 212 | 60 | Study on Value Added Services for Short Message Service | 263d? | 2006-12-06 A | 2007-12-07 | 60% | 105.2d? | 2006-12-06 | 2007-12-07 | 263d? | 723d | finish no earlier than 2007-12-07 | S1 | 2104h | 1262.4h | VAS4SMS | Wu Bin (China Mobile Communications Corporation) | wubin@chinamobile.com | Rel-8 | Alain | 22.xxx |  |  |
| 213 | 61 | Study on Requirements for seamless roaming and service continuity between mobile and WLAN networks | 262d? | 2006-12-06 A | 2007-12-06 | 20% | 209.6d? | 2006-12-06 | 2007-12-06 | 262d? | 724d | finish no earlier than 2007-12-06 | S1 | 2096h | 419.2h | SMLSWLAN | Mike Meyerstein (BT) | mike.meyerstein@bt.com | Rel-8 | Alain | 22.937 |  |  |
| 214 | 62 | Feasibility Study of Mobility between 3GPP-WLAN Interworking and 3GPP Systems | 129d? | 2007-03-20 A | 2007-09-14 A | 100% |  | 2007-03-20 | 2007-09-14 | 129d? |  | start no earlier than 2007-03-20 | S2 | 1032h | 1032h | SM3GWLAN | Orange | orange | Rel-8 | Maurice | 23.837 |  |  |

Notes:
- 183: Corrected by CT#37
- 186: Moved from Rel7
- 187: Moved from Rel7
- 192: New WID approved SP-34. Supporting companies: Telcordia, Samsung, Qualcomm, BT, LG Electronics, Cingular, Alcatel-Lucent. No scheduled end date!
- 193: Added by MCC as a consequence of the move to Rel8 of TISPAN Rel-2 impacts on 3GPP
- 199: WID approved SA#35
- 203: Study approved SA#32
- 205: Acronym changed from "PWS-SI" to "FSPWS"
- 206: Formerly called "Consumer protection against spam and malware"
- 207: Rapporteur update S2#59
- 208: Approved at SP#33
- 213: Revised at SA#36
- 214: Rapporteur name to be provided. Supporting companies: T-Mobile, Orange, China Mobile, Telenor, Alcatel-Lucent, Azaire Networks, Airvana. TR will be stopped when Spec WID is approved

| ID | WBS | Task | Duration | Start | Finish | Complete | Remaining | Baseline start | Baseline finish | Baseline duration | Total slack | Constraint | Resources | Work | Actual work | Text1 | Text6 | Text8 | Text3 | Text4 | Text12 | Text5 | Text7 |
| --- | --- | --- | --- | --- | --- | --- | --- | --- | --- | --- | --- | --- | --- | --- | --- | --- | --- | --- | --- | --- | --- | --- | --- |
| 215 | 63 | **OAM&P Rel-8 Studies** | 936d? | 2006-05-10 A | 2009-12-09 | 55% | 420.65d? | 2005-09-02 | 2008-06-12 | 725d? | 200d |  | S5 | 21905.6h | 9320.4h | OAM8-Studies | Rel-8 | Adrian |  |  |  |  |  |
| 216 | 63.1 | Study of Element Operations Systems Function (EOSF) definition | 655d? | 2007-06-07 A | 2009-12-09 | 30% | 458.5d? | 2005-09-02 | 2007-12-14 | 596d? | 200d | finish no earlier than 2008-03-06 | S5 | 5240h | 1572h |  | Rel-8 |  | TR 32.819 | China Mobile | SP-32 |  |  |
| 217 | 63.2 | Study on SA5 MTOSI XML Harmonization | 418d? | 2006-05-10 A | 2007-12-14 A | 100% |  | 2006-05-10 | 2007-12-14 | 418d? |  | finish no earlier than 2007-12-14 | S5 | 3344h | 3344h |  | Rel-8 |  | TR 32.818 | Nortel | SP-32 |  |  |
| 218 | 63.3 | Study of Common Profile Storage (CPS) Framework of User Data for network services and management | 244d? | 2006-07-03 A | 2007-06-07 A | 100% |  | 2006-07-03 | 2007-06-07 | 244d? |  | finish no earlier than 2007-06-07 | S5 | 1952h | 1952h |  | Rel-8 |  | TR 32.808 | T-Mobile |  |  |  |
| 219 | 63.4 | Study of Management for LTE and SAE | 267d? | 2006-12-07 A | 2007-12-14 | 65% | 93.45d? | 2006-12-07 | 2007-09-14 | 202d? | 718d | finish no earlier than 2007-12-14 | S5 | 2136h | 1388.4h |  | Rel-8 |  | TR 32.816 | Ericsson |  |  |  |
| 220 | 63.5 | Study of System Maintenance by Itf-N | 266d? | 2007-06-07 A | 2008-06-12 | 30% | 186.2d? | 2007-06-07 | 2008-06-12 | 266d? | 589d | finish no earlier than 2008-06-12 | S5 | 2128h | 638.4h |  | Rel-8 |  | TR 32.8xy | ZTE |  |  |  |
| 221 | 63.6 | Study of Self-Organizing Networks (SON) related OAM interfaces for Home NodeB | 266d? | 2007-06-07 A | 2008-06-12 | 20% | 212.8d? | 2007-06-07 | 2008-06-12 | 266d? | 589d | finish no earlier than 2008-06-12 | S5 | 2128h | 425.6h |  | Rel-8 |  | TR 32.8xy | Huawei |  |  |  |
| 222 | 64 | SI on AS-MRFC media server control protocol | 458d? | 2006-03-22 A | 2007-12-21 | 77% | 105.34d? | 2006-03-22 | 2007-12-21 | 458d? | 713d | finish no earlier than 2007-12-21 | C1 | 3664h | 2821.28h | MRFC | Rel-8 |  | New TR 24.880 | Mark Syrett (Hewlett-Packard) |  |  |  |
| 223 | 65 | FS Restoration Procedures | 180d? | 2007-03-26 A | 2007-11-30 | 40% | 108d? | 2007-03-26 | 2007-11-30 | 180d? | 728d | start no earlier than 2007-03-26 | C4 | 1440h | 576h | FSIMS8_RP | Rel-8 | Kimmo | TR 23.820 | German Blanco (Ericsson) |  | german.blanco@ericsson.com |  |
| 224 | 66 | FS on 3G Home NodeB/eNodeB | 210d? | 2007-03-05 A | 2007-12-21 | 10% | 189d? | 2007-03-05 | 2007-12-21 | 210d? | 713d | finish no earlier than 2007-12-21 | R4 | 1680h | 168h | RANFS-HNBeNB | Rel-8 | Claude |  | Howard Thomas (Motorola) |  |  |  |
| 225 | 67 | FS on Multimedia Session Continuity | 232d? | 2007-04-26 A | 2008-03-14 | 60% | 92.8d? | 2007-04-26 | 2008-03-14 | 232d? | 653d | finish no earlier than 2008-03-14 | S2 | 1856h | 1113.6h | MMSC_FS | Rel-8 | Maurice | 23.893 | Jaeseung Song (LG Electronics) |  |  |  |
| 226 | 68 | FS on CS Domain Services over evolved PS access | 233d? | 2007-04-25 A | 2008-03-14 | 70% | 69.9d? | 2007-04-25 | 2008-03-14 | 233d? | 653d | finish no earlier than 2008-03-14 | S2 | 1864h | 1304.8h | FS_CSoPS | Rel-8 | Maurice | 23.879 | Sabine Demel (T-Mobile International) |  | Sabine(dot)Demel(at)T-Mobile(dot)at |  |
| 227 | 69 | FS on Transferring of emergency call data – in-band modem solution | 466d? | 2006-12-07 A | 2008-09-18 | 60% | 186.4d? | 2006-12-07 | 2008-09-18 | 466d? | 519d | finish no earlier than 2008-09-18 | S4 | 3728h | 2236.8h | eCALLIBMS | Rel-8 | Paolo | 26.967 | Leon Hong, Airbiquity |  | lhong@airbiquity.com |  |
| 228 | 70 | FS on Improved network controlled mobility between LTE and 3GPP2/mobile WiMAX radio technologies | 131d? | 2007-06-04 A | 2007-12-03 | 50% | 65.5d? | 2007-06-04 | 2007-12-03 | 131d? | 727d | finish no earlier than 2007-12-03 | R2 | 1048h | 524h | RANFS-LTEmob | Rel-8 | Claude | 25.9xx | Hao Bi, Motorola |  | hao.bi@Motorola.com |  |
| 229 | 71 | FS on IMS Application Server Service Data Descriptions for AS interoperability | 131d? | 2007-09-14 A | 2008-03-14 | 5% | 124.45d? | 2007-09-14 | 2008-03-14 | 131d? | 653d | finish no earlier than 2008-03-14 | C4 | 1048h | 52.4h | FSIMS8_ASIO | Rel-8 | Kimmo | TR 29.864 | Nigel Berry (Alcatel-Lucent |  | nhberry@ALCATEL-LUCENT.COM |  |
| 230 | 72 | FS on CAT solution for voice and video call in CS domain | 131d? | 2007-09-14 A | 2008-03-14 | 5% | 124.45d? | 2007-09-14 | 2008-03-14 | 131d? | 653d | finish no earlier than 2008-03-14 | C4 | 1048h | 52.4h | FSCusAlert-St3 | Rel-8 | Kimmo | TR 29.882 | Zhang Hao (China Mobile) |  | zhanghao@chinamobile.com |  |
| 231 | 73 | **(FS on) 3GPP System Architecture Evolution** | 736d? | 2004-12-03 A | 2007-09-28 | 95% | 38.13d? | 2004-12-03 | 2007-09-28 | 736d? | 773d |  | S2 | 11864h | 11249.4h | SAE | Rel-8 | Dioniso |  |  |  |  | TSG |
| 232 | 73.1 | Stage 2 Interim conclusion for RAN Work to start | 211d? | 2004-12-03 A | 2005-09-23 A | 100% |  | 2004-12-03 | 2005-09-23 | 211d? |  | finish no earlier than 2005-09-23 | S2 | 1688h | 1688h |  | Rel-8 |  | 23.882 |  |  |  |  |
| 233 | 73.2 | Stage 2 Feasibility study on 3GPP architectural development | 450d? | 2006-01-09 A | 2007-09-28 A | 100% |  | 2006-01-09 | 2007-09-28 | 450d? |  | finish no earlier than 2007-09-28 | S2 | 3600h | 3600h |  | Rel-8 | Maurice | 23.882 | Chris Pudney |  |  |  |
| 234 | 73.3 | Security study for Inter-access mobility between non 3GPP and 3GPP system | 86d? | 2006-02-03 A | 2006-06-02 | 55% | 38.7d? | 2006-02-03 | 2006-06-02 | 86d? | 1118d | start no earlier than 2006-02-03 | S3 | 688h | 378.4h | SAE-Sec | Rel-8 | Dioniso | 23.882, 33.821, 33.922 | Dajiang Zhang (Nokia) |  | dajiang.zhang@NOKIA.COM |  |
| 235 | 74 | FS on Scope of future HSPA Evolution for 1.28Mcps TDD | 175d? | 2007-09-14 | 2008-05-15 |  |  | 2007-09-14 | 2008-05-15 | 175d? | 609d | finish no earlier than 2008-05-15 | R1 | 1400h |  | RANFS-LCRTDDHSPAEvo | Rel-8 | Claude | TR 25.9xx | Xu Fei, RITT |  |  |  |
| 236 | 75 | FS on Synchronised E-DCH for UTRA FDD | 131d? | 2007-09-14 | 2008-03-14 |  |  | 2007-09-14 | 2008-03-14 | 131d? | 653d | finish no earlier than 2008-03-14 | R1 | 1048h |  | RANFS-UplinkSync | Rel-8 | Claude | TR 25.9xx | Karri Ranta-aho, Nokia Siemens Networks |  | Karri.Ranta-aho@nsn.com |  |
| 237 | 76 | FS on Extended Support of IMS Emergency Calls | 125d? | 2007-09-24 A | 2008-03-14 | 5% | 118.75d? | 2007-09-24 | 2008-03-14 | 125d? | 653d | finish no earlier than 2008-03-14 | S2 | 1000h | 50h | FSExIMSEm | Rel-8 | Maurice | 23.868 | Stephen Edge (Qualcomm) |  |  |  |
| 238 | 77 | (FS on) Service continuity between mobile and WLAN networks | 75d? | 2007-09-03 | 2007-12-14 |  |  | 2007-09-03 | 2007-12-14 | 75d? | 718d | finish no earlier than 2007-12-14 | S1 | 600h |  | FSSCMobToW | Rel-8 |  | 22.937 | Mike Meyerstein, BT |  | mike.meyerstein@bt.com |  |

Notes:
- 215: Created to encompass the Rel7 Work Tasks shifted to Rel8
- 216: Request to TSG#35 to move to Release 8
- 217: Request to TSG#35 to move to Release 8
- 218: Submit Exception Sheet for TSG#35 Approval
- 219: 12/2006 SA#34 WID approved
- 225: SID approved at SP-36. Updated as SP-37. For information to SA#38
- 226: SID approved at SP-36. TR for information to SA#38
- 227: Moved from Rel7
- 231: Moved from Rel-7
- 232: Moved from Rel-7
- 233: Moved from Rel-7
- 234: Moved from Rel-7
- 237: Approved SP-37

| ID | WBS | Task | Duration | Start | Finish | Complete | Baseline start | Baseline finish | Baseline duration | Total slack | Constraint | Resources | Work | Actual work | Text1 | Text3 | Text4 | Text5 | Text6 | Text8 |
| --- | --- | --- | --- | --- | --- | --- | --- | --- | --- | --- | --- | --- | --- | --- | --- | --- | --- | --- | --- | --- |
| 239 | 78 | **FS on enhanced voice service requirements for the EPS** | 140d? | 2007-09-03 | 2008-03-14 |  | 2007-09-03 | 2008-03-14 | 140d? | 653d |  | S1 | 3360h |  | FSEV_EPS | new TR 22.xxx | Tim Haysom, Orange | tim.haysom@orange-ftgroup.com | Rel-8 |  |
| 240 | 78.1 | Use cases definition and service and system requirements | 140d? | 2007-09-03 | 2008-03-14 |  |  |  |  | 653d | start no earlier than 2007-09-03 | S1 | 1120h |  | FSEV_EPS-S1 |  | Tim Haysom, Orange | tim.haysom@orange-ftgroup.com | Rel-8 |  |
| 241 | 78.2 | Codec specific part of FSEV_EPS | 140d? | 2007-09-03 | 2008-03-14 |  |  |  |  | 653d | start no earlier than 2007-09-03 | S4 | 1120h |  | FSEV_EPS-S4 |  | Tim Haysom, Orange | tim.haysom@orange-ftgroup.com | Rel-8 |  |
| 242 | 79 | DELETE - Study on GAN Enhancements | 206d? | 2006-11-17 A | 2007-08-31 A | 100% | 2006-11-17 | 2007-08-31 | 206d? |  | start no earlier than 2006-11-17 | GP | 1648h | 1648h | EGAN | 43.902 | Janne Linkola (T-Mobile) | janne.linkola@t-mobile.com | Rel-7 | Paolo |

Notes:
- 242: Completed for Rel7
